# A2 TRAMO I - LACRAMARCA.REV.02

How a schedule from Primavera P6 changed from version to version. A marks actual dates.

## Version 1 (data date 2023-11-05, saved 2023-10-26, file CRONOGRAMA A2 TRAMO I - LACRAMARCA. REV.02.xer)

| ID | WBS | Task | Duration | Start | Finish | Predecessors | Total float |
| --- | --- | --- | --- | --- | --- | --- | --- |
|  | 1 | **HITOS** |  | 2023-11-06 | 2023-11-09 |  |  |
| A1010 |  | BUENA PRO | 0d | 2023-11-06 | 2023-11-06 |  | 0d |
| A1020 |  | KICK OF MEETING (KMO) | 0d | 2023-11-09 | 2023-11-09 | A1010 SS+3.9d | 0d |
|  | 2 | **INICIO DE PLAZO CONTRACTUAL - FIN DE OBRA** |  | 2023-11-24 | 2025-02-15 |  |  |
| A1030 |  | INICIO DEL PLAZO CONTRACTUAL - ACCESO AL SITIO | 0d | 2023-11-24 | 2023-11-24 | A1020 SS+14.5d | 0d |
| A1070 |  | INICIO DE DIQUE MARGEN IZQUIERDA | 0d | 2023-11-28 | 2023-11-28 | 1.07.100 SS | 445.96d |
| A1040 |  | INICIO DE EXCAVACIÓN | 0d | 2023-11-28 | 2023-11-28 | A1030 SS+4.4d | 44.65d |
| A1050 |  | INICIO DE RELLENO DE DIQUE | 0d | 2023-12-04 | 2023-12-04 | A1040 SS+5.5d | 57.75d |
| A1110 |  | INICIO DE DIQUE MARGEN DERECHA | 0d | 2023-12-27 | 2023-12-27 | 1.07.500 SS | 416.96d |
| A1130 |  | INICIO DE DIQUE INTERFERENCIAS | 0d | 2024-03-11 | 2024-03-11 | 1.07.710 SS | 341.96d |
| A1150 |  | INICIO DE DIQUE LIBERACIÓN PREDIAL | 0d | 2024-04-11 | 2024-04-11 | 1.07.730 SS | 310.9d |
| A1230 |  | FIN DE DIQUE INTERFERENCIAS | 0d | 2024-06-06 | 2024-06-06 | 1.07.810 FF | 254.37d |
| A1260 |  | FIN DE DIQUE LIBERACIÓN PREDIAL | 0d | 2024-11-23 | 2024-11-23 | 1.07.840 FF | 84.9d |
| A1210 |  | FIN DE DIQUE MARGEN DERECHA | 0d | 2025-01-20 | 2025-01-20 | 1.07.235 FF | 26.37d |
| A1200 |  | FIN DE DIQUE MARGEN IZQUIERDA | 0d | 2025-01-21 | 2025-01-21 | 1.07.234 FF | 25.12d |
| A1270 |  | FIN DE OBRA | 0d | 2025-02-15 | 2025-02-15 | 01.10.03 FF+0.3d | 0d |
|  | 3 | **CONSTRUCCIÓN SUB PROYECTO A2 TRAMO I-RÍO LACRAMARCA** |  | 2023-11-24 | 2025-02-15 |  |  |
|  | 1 | **SUBPROYECTO A2 TRAMO I (OPCIÓN A)** |  | 2023-11-24 | 2025-02-08 |  |  |
|  | 1 | **DEFENSAS RIBEREÑAS** |  | 2023-11-24 | 2025-02-08 |  |  |
|  | 1 | **OBRAS PRELIMINARES** |  | 2023-11-28 | 2025-02-05 |  |  |
| 1.01.02 |  | INSTALACIONES PROVISIONALES PARA LA OBRA | 0.5d | 2023-11-28 | 2023-11-28 | 01.02.01 FS-10.4d | 8.68d |
| 1.01.03 |  | MANTENIMIENTO DE TRÁNSITO Y SEGURIDAD VIAL | 359.5d | 2023-11-28 | 2025-02-05 | 1.01.02 SS | 8.68d |
|  | 2 | **TRABAJOS PRELIMINARES** |  | 2023-11-24 | 2025-02-08 |  |  |
| 01.02.01 |  | MOVILIZACIÓN DE EQUIPOS | 13.76d | 2023-11-24 | 2023-12-12 | A1030 SS-0.4d | 0d |
| 01.02.02 |  | TOPOGRAFÍA Y GEOREFERENCIACIÓN | 362.5d | 2023-11-28 | 2025-02-08 | A1030 SS+4d | 5.67d |
|  | 3 | **DIQUES DE TIERRA COMPACTADA CON ENROCADO** |  | 2023-12-12 | 2024-11-11 |  |  |
|  | 1 | **COLOCACION Y ACOMODO DE ROCA EN UÑA DE DIQUE** |  | 2023-12-12 | 2024-11-11 |  |  |
| 1.03.612 |  | COLOCACION Y ACOMODO DE ROCA EN UÑA DE DIQUE A2-I-01-B | 3.5d | 2023-12-12 | 2023-12-15 | 1.07.622 FS+0.5d | 45.55d |
| 1.03.613 |  | COLOCACION Y ACOMODO DE ROCA EN UÑA DE DIQUE A2-I-03 | 3.5d | 2024-01-08 | 2024-01-11 | 1.07.623 FS+0.5d | 324.05d |
| 1.03.611 |  | COLOCACION Y ACOMODO DE ROCA EN UÑA DE DIQUE A2-I-01 | 4.5d | 2024-01-23 | 2024-01-27 | 1.07.621 FS+0.5d | 314.05d |
| 1.03.617 |  | COLOCACION Y ACOMODO DE ROCA EN UÑA DE DIQUE A2-D-02 | 2.5d | 2024-03-20 | 2024-03-22 | 1.07.626 FS+0.5d | 264.05d |
| 1.03.618 |  | COLOCACION Y ACOMODO DE ROCA EN UÑA DE DIQUE INTERFERENCIA SEDACHIMBOTE | 11.5d | 2024-05-07 | 2024-05-20 | 1.07.627 FS+0.5d | 211.05d |
| 1.03.619 |  | COLOCACION Y ACOMODO DE ROCA EN UÑA DE DIQUE INTERFERENCIA QUAVI | 5.5d | 2024-05-11 | 2024-05-17 | 1.07.628 FS+0.5d | 220.05d |
| 1.03.620 |  | COLOCACION Y ACOMODO DE ROCA EN UÑA DE DIQUE LIBERACIÓN PREDIAL LI | 5.5d | 2024-05-20 | 2024-05-25 | 1.07.629 FS+0.5d | 206.05d |
| 1.03.614 |  | COLOCACION Y ACOMODO DE ROCA EN UÑA DE DIQUE A2-I-02 | 63.5d | 2024-07-26 | 2024-10-11 | 1.07.624 FS+0.5d | 0d |
| 1.03.621 |  | COLOCACION Y ACOMODO DE ROCA EN UÑA DE DIQUE LIBERACIÓN PREDIAL LD | 29.5d | 2024-08-26 | 2024-10-01 | 1.07.630 FS+0.5d | 70.55d |
| 1.03.616 |  | COLOCACION Y ACOMODO DE ROCA EN UÑA DE DIQUE A2-D-01 | 48.5d | 2024-09-13 | 2024-11-11 | 1.07.625 FS+0.5d | 23.05d |
|  | 4 | **OBRAS DE ARTE (TOMAS Y RETORNOS)** |  | 2024-08-28 | 2025-02-05 |  |  |
|  | 1 | **TOMAS O CAPTACIONES** |  | 2024-08-28 | 2025-02-05 |  |  |
|  | 1 | **OBRAS DE CONCRETO** |  | 2024-10-02 | 2025-02-03 |  |  |
| 1.04.01 |  | CONCRETO f'c=100 kg/cm2 | 0.53d | 2024-10-02 | 2024-10-02 | 1.08.02 FS+0.5d | 8.81d |
| 1.04.05 |  | ACERO DE REFUERZO fy=4200 kg/cm2 | 50.65d | 2024-10-03 | 2024-12-03 | 1.04.01 FS+0.53d | 8.81d |
| 1.04.04 |  | ENCOFRADO Y DESENCOFRADO RECTO | 36.5d | 2024-12-04 | 2025-01-17 | 1.04.05 FS+0.5d | 8.81d |
| 1.04.02 |  | CONCRETO f'c=280 kg/cm2 | 9.5d | 2025-01-18 | 2025-01-29 | 1.04.04 FS+0.5d | 8.81d |
| 1.04.03 |  | CONCRETO CICLÓPEO f'c=280 kg/cm2 + 30% P.G. | 3.5d | 2025-01-30 | 2025-02-03 | 1.04.02 FS+0.5d | 10.84d |
|  | 3 | **ESTRUCTURAS METÁLICAS** |  | 2025-01-30 | 2025-02-05 |  |  |
| 1.04.06 |  | COMPUERTA METALICA PLANA DESLIZANTE DE 1.0x1.0 m | 2.5d | 2025-01-30 | 2025-02-01 | 1.04.02 FS+0.5d | 8.81d |
| 1.04.10 |  | BARANDA DE FIERRO GALVANIZADO 1 1/2" | 0.53d | 2025-01-30 | 2025-01-30 | 1.04.06 SS | 8.81d |
| 1.04.07 |  | COMPUERTA METALICA PLANA DESLIZANTE DE 1.5x1.0 m | 0.53d | 2025-01-30 | 2025-01-31 | 1.04.06 FS-2d | 12.23d |
| 1.04.08 |  | REJILLA METÁLICA DE 1.00x1.00m | 0.53d | 2025-01-31 | 2025-02-01 | 1.04.07 FS+0.5d | 12.23d |
| 1.04.09 |  | REJILLA METÁLICA DE 1.50x1.00m | 0.5d | 2025-01-31 | 2025-02-01 | 1.04.08 FS-0.45d | 12.23d |
| 1.04.11 |  | ESCALERA TIPO GATO | 1.5d | 2025-02-01 | 2025-02-03 | 1.04.10 FS+1.5d | 8.81d |
| 1.04.12 |  | TAPA DE CONCRETO | 1.5d | 2025-02-04 | 2025-02-05 | 1.04.11 FS+0.5d | 8.81d |
|  | 2 | **TUBERÍAS** |  | 2024-08-28 | 2024-11-14 |  |  |
| 1.04.13 |  | EXCAVACIÓN ESTRUCTURAL PARA OBRAS DE ARTE (buzones) | 1.5d | 2024-08-28 | 2024-08-29 | 1.08.01 SS+0.2d | 77.85d |
| 1.04.14 |  | EXCAVACIÓN DE ZANJA | 15.5d | 2024-08-31 | 2024-09-18 | 1.04.13 FS+0.5d | 77.85d |
| 1.04.16 |  | CAMA DE ARENA | 2.5d | 2024-09-19 | 2024-09-21 | 1.04.14 FS+0.5d | 77.85d |
| 1.04.24 |  | SUMINISTRO E INSTALACIÓN DE TUBERÍA GRP DN600 mm SN2500 | 10.5d | 2024-09-23 | 2024-10-04 | 1.04.16 FS+0.5d | 77.85d |
| 1.04.17 |  | RELLENO SELECCIONADO PARA ZANJA con material propio | 7.5d | 2024-10-05 | 2024-10-15 | 1.04.24 FS+0.5d | 77.85d |
| 1.04.23 |  | ACERO DE REFUERZO fy=4200 kg/cm2 | 3.5d | 2024-10-16 | 2024-10-19 | 1.04.17 FS+0.5d | 77.85d |
| 1.04.21 |  | ENCOFRADO Y DESENCOFRADO RECTO | 4.5d | 2024-10-21 | 2024-10-25 | 1.04.23 FS+0.5d | 77.85d |
| 1.04.22 |  | ENCOFRADO Y DESENCOFRADO CURVO | 8.5d | 2024-10-26 | 2024-11-06 | 1.04.21 FS+0.5d | 77.85d |
| 1.04.20 |  | CONCRETO f'c=280 kg/cm2 (buzones) | 0.5d | 2024-11-07 | 2024-11-07 | 1.04.22 FS+0.5d | 77.85d |
| 1.04.15 |  | RELLENO ESTRUCTURAL PARA OBRAS DE ARTE, CON MATERIAL PROPIO | 5.5d | 2024-11-08 | 2024-11-14 | 1.04.20 FS+0.5d | 77.85d |
|  | 4 | **CANALES** |  | 2024-10-12 | 2024-11-20 |  |  |
| 1.04.25 |  | CONCRETO f'c=100 kg/cm2 | 0.5d | 2024-10-12 | 2024-10-12 | 1.08.04 FS+0.5d | 72.99d |
| 1.04.28 |  | ACERO DE REFUERZO fy=4200 kg/cm2 | 16.5d | 2024-10-14 | 2024-11-02 | 1.04.25 FS+0.5d | 72.99d |
| 1.04.27 |  | ENCOFRADO Y DESENCOFRADO RECTO | 13.5d | 2024-11-04 | 2024-11-19 | 1.04.28 FS+0.5d | 72.99d |
| 1.04.26 |  | CONCRETO f'c=280 kg/cm2 | 0.53d | 2024-11-20 | 2024-11-20 | 1.04.27 FS+0.53d | 72.99d |
| 1.04.29 |  | JUNTA WATER STOP SIN BULBO 150 mm | 0.53d | 2024-11-20 | 2024-11-20 | 1.04.26 SS | 72.99d |

| ID | WBS | Task | Duration | Start | Finish | Predecessors | Total float |
| --- | --- | --- | --- | --- | --- | --- | --- |
|  | 5 | **OBRAS DE DESCARGA** |  | 2024-10-12 | 2024-10-29 |  |  |
| 1.04.30 |  | CONCRETO f'c=100 kg/cm2 | 0.5d | 2024-10-12 | 2024-10-12 | 1.08.04 FS+0.5d | 90.65d |
| 1.04.33 |  | ACERO DE REFUERZO fy=4200 kg/cm2 | 2.5d | 2024-10-14 | 2024-10-16 | 1.04.30 FS+0.5d | 90.65d |
| 1.04.32 |  | ENCOFRADO Y DESENCOFRADO RECTO | 9.5d | 2024-10-17 | 2024-10-28 | 1.04.33 FS+0.5d | 90.65d |
| 1.04.31 |  | CONCRETO f'c=280 kg/cm2 | 0.5d | 2024-10-29 | 2024-10-29 | 1.04.32 FS+0.5d | 90.65d |
| 1.04.34 |  | JUNTA WATER STOP SIN BULBO 150 mm | 0.5d | 2024-10-29 | 2024-10-29 | 1.04.31 FS-0.1d | 90.65d |
|  | 6 | **RETORNOS** |  | 2024-10-15 | 2024-12-19 |  |  |
|  | 1 | **RETORNOS TIPO A2-OA-RE-I-11-25** |  | 2024-10-17 | 2024-11-15 |  |  |
|  | 1 | **OBRAS DE CONCRETO** |  | 2024-10-17 | 2024-11-12 |  |  |
| 1.04.35 |  | CONCRETO f'c=100 kg/cm2 | 0.5d | 2024-10-17 | 2024-10-17 | 1.08.08 FS+0.5d | 76.78d |
| 1.04.38 |  | ACERO DE REFUERZO fy=4200 kg/cm2 | 9.5d | 2024-10-18 | 2024-10-29 | 1.04.35 FS+0.5d | 76.78d |
| 1.04.37 |  | ENCOFRADO Y DESENCOFRADO RECTO | 8.5d | 2024-10-30 | 2024-11-09 | 1.04.38 FS+0.5d | 76.78d |
| 1.04.36 |  | CONCRETO f'c=280 kg/cm2 | 0.5d | 2024-11-11 | 2024-11-11 | 1.04.37 FS+0.5d | 76.78d |
| 1.04.39 |  | JUNTA WATER STOP SIN BULBO 150 mm | 1.59d | 2024-11-11 | 2024-11-12 | 1.04.36 SS | 79.69d |
|  | 2 | **ESTRUCTURAS METALICAS** |  | 2024-11-12 | 2024-11-15 |  |  |
| 1.04.40 |  | COMPUERTA METALICA PLANA DESLIZANTE DE 1.0x1.0 m | 1.5d | 2024-11-12 | 2024-11-13 | 1.04.36 FS+0.5d | 76.78d |
| 1.04.41 |  | BARANDA DE FIERRO GALVANIZADO 1 1/2" | 1.5d | 2024-11-14 | 2024-11-15 | 1.04.40 FS+0.5d | 76.78d |
|  | 2 | **RETORNOS Q=100 A 1000 l/s** |  | 2024-10-15 | 2024-12-19 |  |  |
|  | 1 | **OBRAS DE CONCRETO** |  | 2024-10-30 | 2024-11-30 |  |  |
| 1.04.42 |  | CONCRETO f'c=100 kg/cm2 | 0.53d | 2024-10-30 | 2024-10-30 | 1.08.11 FS+0.47d, 1.04.46 FF-1.5d | 47.83d |
| 1.04.45 |  | ACERO DE REFUERZO fy=4200 kg/cm2 | 14.76d | 2024-10-31 | 2024-11-18 | 1.04.42 FS+0.42d | 47.83d |
| 1.04.44 |  | ENCOFRADO Y DESENCOFRADO RECTO | 9.5d | 2024-11-19 | 2024-11-29 | 1.04.45 FS+0.5d | 47.83d |
| 1.04.43 |  | CONCRETO f'c=280 kg/cm2 | 0.5d | 2024-11-30 | 2024-11-30 | 1.04.44 FS+0.5d | 47.83d |
|  | 2 | **TUBERÍAS** |  | 2024-10-15 | 2024-10-28 |  |  |
| 1.04.46 |  | SUMINISTRO E INSTALACIÓN DE TUBERÍA HDPE DN600 mm | 11.5d | 2024-10-15 | 2024-10-28 | 1.08.10 FS+0.5d | 51.33d |
|  | 3 | **COMPUERTAS Y VÁLVULAS** |  | 2024-12-02 | 2024-12-19 |  |  |
| 1.04.47 |  | COMPUERTA TIPO CLAPETA DN600 mm | 15.5d | 2024-12-02 | 2024-12-19 | 1.04.43 FS+0.5d | 47.83d |
|  | 5 | **ARQUITECTURA Y PAISAJISMO** |  | 2024-10-23 | 2024-11-05 |  |  |
|  | 1 | **INTERVENCION PAISAJISMO - CRUCE AVENIDA PERU** |  | 2024-10-23 | 2024-11-05 |  |  |
|  | 1 | **OBRAS PRELIMINARES** |  | 2024-10-23 | 2024-11-05 |  |  |
| 1.05.01 |  | MOVILIZACIÓN Y DEMOVILIZACIÓN DE EQUIPOS Y HERRAMIENTAS (ARQUITECTURA Y PAISAJISMO) | 2.5d | 2024-10-23 | 2024-10-25 | 1.05.03 FS-4.5d | 87.94d |
| 1.05.02 |  | TRAZO Y REPLANTEO PRELIMINAR | 6.5d | 2024-10-28 | 2024-11-05 | 1.05.03 SS-0.1d | 85.97d |
|  | 2 | **MOBILIARIOS, BARANDAS Y ESCALERAS** |  | 2024-10-28 | 2024-11-05 |  |  |
| 1.05.03 |  | ESCALERA DE CONCRETO SOBRE ENROCADO, CIMENTACION Y ANCLAJE | 0.53d | 2024-10-28 | 2024-10-28 | 1.09.22 FS+0.53d | 85.69d |
| 1.05.04 |  | BARANDA DE MADERA EUCALIPTO CON SOGA, INCLUYE CIMENTACIÓN | 0.5d | 2024-10-29 | 2024-10-29 | 1.05.03 FS+0.5d | 85.69d |
| 1.05.05 |  | TACHOS DE BASURA, INCLUYE CIMENTACIÓN | 0.53d | 2024-10-30 | 2024-10-30 | 1.05.04 FS+0.53d | 85.69d |
| 1.05.06 |  | BANCAS DE CONCRETO, INCLUYE CIMENTACIÓN | 0.53d | 2024-10-31 | 2024-10-31 | 1.05.05 FS+0.53d | 85.69d |
| 1.05.07 |  | POSTES DE ILUMINACIÓN, INCLUYE LUMINARIA Y CIMENTACIÓN | 1.5d | 2024-11-02 | 2024-11-04 | 1.05.06 FS+0.53d | 85.69d |
| 1.05.08 |  | SEÑALETICA INFORMATIVA | 0.5d | 2024-11-05 | 2024-11-05 | 1.05.07 FS+0.5d | 85.69d |
|  | 2 | **SUBPROYECTO A2 TRAMO I (OPCIÓN B)** |  | 2023-11-28 | 2025-02-15 |  |  |
|  | 1 | **DEFENSAS RIBEREÑAS** |  | 2023-11-28 | 2025-02-15 |  |  |
|  | 1 | **MEJORAMIENTO DE VÍAS EXISTENTES** |  | 2023-11-28 | 2024-06-04 |  |  |
| 1.06.01 |  | ROCE Y LIMPIEZA DE MALEZA | 5.5d | 2023-11-28 | 2023-12-04 | A1040 SS-0.4d | 212.67d |
| 1.06.02 |  | REHABILITACIÓN DE VÍAS EXISTENTES | 149.5d | 2023-12-05 | 2024-06-04 | 1.06.01 FS+0.5d | 212.67d |
| 1.06.03 |  | CONFORMACIÓN DE TERRAPLENES EN CAMINO | 2.53d | 2023-12-05 | 2023-12-07 | 1.06.01 FS+0.5d | 359.64d |
|  | 2 | **DESCOLMATACIÓN DE CAUCE Y OBRAS AUXILIARES** |  | 2023-11-28 | 2024-03-06 |  |  |
| 1.07.01 |  | DESBROCE Y LIMPIEZA EN ZONA NO BOSCOSA | 16.5d | 2023-11-28 | 2023-12-19 | A1040 SS-0.4d | 351.67d |
| 1.07.02 |  | DESCOLMATACIÓN DE DESCOLMATACIÓN DE CAUCE NATURAL DEL RÍO LACRAMARCA | 56.5d | 2023-11-28 | 2024-02-06 | A1040 SS-0.4d | 286.57d |
| 1.07.03 |  | CONFORMACIÓN DE DESVIO EN CAUCE DE RÍO | 34.5d | 2023-12-05 | 2024-01-18 | 1.07.02 SS+6d | 286.57d |
| 1.07.04 |  | RELLENO NO ESTRUCTURAL CON MATERIAL PROPIO (canal) | 46.5d | 2024-01-12 | 2024-03-06 | 1.07.03 FS-5.4d | 286.57d |
|  | 3 | **DIQUES DE TIERRA COMPACTADA CON ENROCADO** |  | 2023-11-28 | 2025-01-21 |  |  |
|  | 1 | **EXCAVACIÓN EN TERRENO NATURAL CON EQUIPO** |  | 2023-11-28 | 2024-05-07 |  |  |
| 1.07.100 |  | EXCAVACIÓN EN TERRENO NATURAL CON EQUIPO (A2-I-01) | 8.5d | 2023-11-28 | 2023-12-07 | 01.02.01 SS+3d | 8.81d |
| 1.07.200 |  | EXCAVACIÓN EN TERRENO NATURAL CON EQUIPO (A2-I-01-B) | 1.5d | 2023-11-28 | 2023-11-29 | 01.02.01 SS+3d | 0d |
| 1.07.400 |  | EXCAVACIÓN EN TERRENO NATURAL CON EQUIPO (A2-I-02) | 51.5d | 2023-12-02 | 2024-02-05 | 1.07.172 FS+0.5d | 0d |
| 1.07.300 |  | EXCAVACIÓN EN TERRENO NATURAL CON EQUIPO (A2-I-03) | 8.5d | 2023-12-13 | 2023-12-22 | 1.07.171 FS+0.5d | 8.81d |
| 1.07.500 |  | EXCAVACIÓN EN TERRENO NATURAL CON EQUIPO (A2-D-01) | 55.5d | 2023-12-27 | 2024-03-01 | 1.07.173 FS+0.5d | 8.81d |
| 1.07.600 |  | EXCAVACIÓN EN TERRENO NATURAL CON EQUIPO (A2-D-02) | 4.5d | 2024-03-04 | 2024-03-08 | 1.07.174 FS+0.5d | 206.05d |
| 1.07.710 |  | EXCAVACIÓN INTERFERENCIA SEDACHIMBOTE | 10.5d | 2024-03-11 | 2024-03-22 | 1.07.176 FS+0.5d | 206.05d |
| 1.07.750 |  | EXCAVACIÓN LIBERACIÓN PREDIAL LD | 36.5d | 2024-03-22 | 2024-05-07 | 1.07.175 FS+0.5d | 8.81d |
| 1.07.720 |  | EXCAVACIÓN INTERFERENCIA QUAVI | 7.5d | 2024-03-30 | 2024-04-08 | 1.07.177 FS+0.5d | 206.05d |
| 1.07.730 |  | EXCAVACIÓN LIBERACIÓN PREDIAL LI | 13.5d | 2024-04-11 | 2024-04-26 | 1.07.178 FS+0.5d | 206.05d |
| 1.07.800 |  | EXCAVACIÓN EN TERRENO NATURAL CON EQUIPO (RAMPAS) | 0.5d | 2024-04-30 | 2024-04-30 | 1.07.179 FS+0.5d | 236.05d |
|  | 2 | **EXCAVACIÓN DE UÑA CON EQUIPO** |  | 2023-11-30 | 2024-05-20 |  |  |
| 1.07.172 |  | EXCAVACIÓN DE UÑA CON EQUIPO (A2-I-01-B) | 1.5d | 2023-11-30 | 2023-12-01 | 1.07.200 FS+0.5d | 0d |
| 1.07.171 |  | EXCAVACIÓN DE UÑA CON EQUIPO (A2-I-01) | 1.5d | 2023-12-11 | 2023-12-12 | 1.07.100 FS+0.5d | 8.81d |
| 1.07.173 |  | EXCAVACIÓN DE UÑA CON EQUIPO (A2-I-03) | 1.5d | 2023-12-23 | 2023-12-26 | 1.07.300 FS+0.5d | 8.81d |
| 1.07.174 |  | EXCAVACIÓN DE UÑA CON EQUIPO (A2-I-02) | 22.5d | 2024-02-06 | 2024-03-02 | 1.07.400 FS+0.5d | 0d |
| 1.07.175 |  | EXCAVACIÓN DE UÑA CON EQUIPO (A2-D-01) | 16.5d | 2024-03-02 | 2024-03-21 | 1.07.500 FS+0.5d | 8.81d |
| 1.07.176 |  | EXCAVACIÓN DE UÑA CON EQUIPO (A2-D-02) | 0.5d | 2024-03-09 | 2024-03-09 | 1.07.600 FS+0.5d | 206.05d |

| ID | WBS | Task | Duration | Start | Finish | Predecessors | Total float |
| --- | --- | --- | --- | --- | --- | --- | --- |
| 1.07.177 |  | EXCAVACIÓN DE UÑA CON EQUIPO INTERFERENCIA SEDACHIMBOTE | 3.5d | 2024-03-23 | 2024-03-27 | 1.07.710 FS+0.5d | 206.05d |
| 1.07.178 |  | EXCAVACIÓN DE UÑA CON EQUIPO INTERFERENCIA QUAVI | 1.5d | 2024-04-09 | 2024-04-10 | 1.07.720 FS+0.5d | 206.05d |
| 1.07.179 |  | EXCAVACIÓN DE UÑA CON EQUIPO LIBERACIÓN PREDIAL LI | 1.5d | 2024-04-27 | 2024-04-29 | 1.07.730 FS+0.5d | 206.05d |
| 1.07.180 |  | EXCAVACIÓN DE UÑA CON EQUIPO LIBERACIÓN PREDIAL LD | 10.5d | 2024-05-08 | 2024-05-20 | 1.07.750 FS+0.5d | 8.81d |
|  | 3 | **PERFILADO Y COMPACTACIÓN EN ZONA DE CORTE EN CORONA** |  | 2023-12-21 | 2025-01-21 |  |  |
| 1.07.232 |  | PERFILADO Y COMPACTACIÓN EN ZONA DE CORTE EN CORONA (A2-I-01-B) | 0.53d | 2023-12-21 | 2023-12-21 | 1.07.552 FS+0.5d | 350.02d |
| 1.07.233 |  | PERFILADO Y COMPACTACIÓN EN ZONA DE CORTE EN CORONA (A2-I-03) | 0.5d | 2024-01-23 | 2024-01-23 | 1.07.553 FS+0.5d | 324.05d |
| 1.07.236 |  | PERFILADO Y COMPACTACIÓN EN ZONA DE CORTE EN CORONA (A2-D-02) | 0.5d | 2024-04-04 | 2024-04-04 | 1.07.556 FS+0.5d | 264.05d |
| 1.07.820 |  | PERFILADO Y COMPACTACIÓN EN ZONA DE CORTE EN CORONA INTERFERENCIA QUAVI | 0.5d | 2024-05-27 | 2024-05-27 | 1.07.558 FS+0.5d | 220.05d |
| 1.07.810 |  | PERFILADO Y COMPACTACIÓN EN ZONA DE CORTE EN CORONA INTERFERENCIA SEDACHIMBOTE | 0.5d | 2024-06-06 | 2024-06-06 | 1.07.557 FS+0.5d | 211.05d |
| 1.07.830 |  | PERFILADO Y COMPACTACIÓN EN ZONA DE CORTE EN CORONA LIBERACIÓN PREDIAL LI | 1.5d | 2024-06-11 | 2024-06-12 | 1.07.559 FS+0.5d | 206.05d |
| 1.07.840 |  | PERFILADO Y COMPACTACIÓN EN ZONA DE CORTE EN CORONA LIBERACIÓN PREDIAL LD | 3.5d | 2024-11-19 | 2024-11-23 | 1.07.560 FS+0.5d | 70.55d |
| 1.07.235 |  | PERFILADO Y COMPACTACIÓN EN ZONA DE CORTE EN CORONA (A2-D-01) | 3.5d | 2025-01-16 | 2025-01-20 | 1.07.555 FS+0.5d | 23.05d |
| 1.07.234 |  | PERFILADO Y COMPACTACIÓN EN ZONA DE CORTE EN CORONA (A2-I-02) | 3.5d | 2025-01-17 | 2025-01-21 | 1.07.554 FS+0.5d | 0d |
|  | 10 | **PERFILADO EN ZONA DE CORTE EN TALUD DE DIQUE** |  | 2023-12-05 | 2024-08-26 |  |  |
| 1.07.292 |  | PERFILADO EN ZONA DE CORTE TALUD DE DIQUE (A2-I-01-B) | 1.5d | 2023-12-05 | 2023-12-06 | 1.07.452 FS+0.5d | 45.55d |
| 1.07.293 |  | PERFILADO EN ZONA DE CORTE TALUD DE DIQUE (A2-I-03) | 3.5d | 2023-12-30 | 2024-01-04 | 1.07.453 FS+0.5d | 324.05d |
| 1.07.291 |  | PERFILADO EN ZONA DE CORTE DE TALUD DE DIQUE (A2-I-01) | 2.5d | 2024-01-17 | 2024-01-19 | 1.07.491 FS+0.5d | 314.05d |
| 1.07.296 |  | PERFILADO EN ZONA DE CORTE DE TALUD DE DIQUE (A2-D-02) | 3.5d | 2024-03-13 | 2024-03-16 | 1.07.456 FS+0.5d | 264.05d |
| 1.07.850 |  | PERFILADO EN ZONA DE CORTE DE TALUD DE DIQUE INTERFERENCIA SEDACHIMBOTE | 5.5d | 2024-04-24 | 2024-04-30 | 1.07.494 FS+0.5d | 211.05d |
| 1.07.860 |  | PERFILADO EN ZONA DE CORTE DE TALUD DE DIQUE QUAVI | 2.5d | 2024-05-06 | 2024-05-08 | 1.07.495 FS+0.5d | 220.05d |
| 1.07.870 |  | PERFILADO EN ZONA DE CORTE DE TALUD DE DIQUE LIBERACIÓN PREDIAL LI | 5.5d | 2024-05-09 | 2024-05-15 | 1.07.496 FS+0.5d | 206.05d |
| 1.07.294 |  | PERFILADO EN ZONA DE CORTE TALUD DE DIQUE (A2-I-02) | 13.5d | 2024-06-17 | 2024-07-03 | 1.07.492 FS+0.5d | 0d |
| 1.07.880 |  | PERFILADO EN ZONA DE CORTE DE TALUD DE DIQUE LIBERACIÓN PREDIAL LD | 8.5d | 2024-08-03 | 2024-08-14 | 1.07.497 FS+0.5d | 70.55d |
| 1.07.295 |  | PERFILADO EN ZONA DE CORTE EN TALUD DE DIQUE (A2-D-01) | 11.5d | 2024-08-13 | 2024-08-26 | 1.07.493 FS+0.5d | 23.05d |
|  | 11 | **PREPARACIÓN DE FUNDACIÓN DE CUERPO DE DIQUE** |  | 2023-12-02 | 2024-05-21 |  |  |
| 1.07.331 |  | PREPARACIÓN DE FUNDACIÓN DE CUERPO DE DIQUE (A2-I-01-B) | 0.5d | 2023-12-02 | 2023-12-02 | 1.07.172 FS+0.5d | 45.55d |
| 1.07.332 |  | PREPARACIÓN DE FUNDACIÓN DE CUERPO DE DIQUE (A2-I-03) | 0.5d | 2023-12-27 | 2023-12-27 | 1.07.173 FS+0.5d | 324.05d |
| 1.07.333 |  | PREPARACIÓN DE FUNDACIÓN DE CUERPO DE DIQUE (A2-I-02) | 4.24d | 2024-03-04 | 2024-03-08 | 1.07.174 FS+0.5d | 0d |
| 1.07.334 |  | PREPARACIÓN DE FUNDACIÓN DE CUERPO DE DIQUE (A2-D-02) | 0.5d | 2024-03-11 | 2024-03-11 | 1.07.176 FS+0.5d | 264.05d |
| 1.07.890 |  | PREPARACIÓN DE FUNDACIÓN DE CUERPO DE DIQUE INTERFERENCIA SEDACHIMBOTE | 0.5d | 2024-03-30 | 2024-03-30 | 1.07.177 FS+0.5d | 211.05d |
| 1.07.910 |  | PREPARACIÓN DE FUNDACIÓN DE CUERPO DE DIQUE LIBERACIÓN PREDIAL LI | 0.5d | 2024-04-30 | 2024-04-30 | 1.07.179 FS+0.5d | 206.05d |
| 1.07.911 |  | PREPARACIÓN DE FUNDACIÓN DE CUERPO DE DIQUE LIBERACIÓN PREDIAL LD | 0.5d | 2024-05-21 | 2024-05-21 | 1.07.180 FS+0.5d | 70.55d |
|  | 4 | **PEDRAPLÉN e=60 cm** |  | 2023-12-13 | 2024-06-27 |  |  |
| 1.07.361 |  | PEDRAPLEN e=60 cm (A2-I-01) | 13.5d | 2023-12-13 | 2023-12-29 | 1.07.171 FS+0.5d | 25.85d |
| 1.07.362 |  | PEDRAPLÉN e=60 cm (A2-I-02) | 15.5d | 2024-03-09 | 2024-03-27 | 1.07.333 FS+1d | 0d |
| 1.07.363 |  | PEDRAPLEN e=60 cm (A2-D-01) | 62.5d | 2024-03-22 | 2024-06-06 | 1.07.175 FS+0.5d | 23.05d |
| 1.07.930 |  | PEDRAPLEN e=60 cm INTERFERENCIA SEDACHIMBOTE | 6.5d | 2024-04-01 | 2024-04-08 | 1.07.890 FS+0.5d | 211.05d |
| 1.07.940 |  | PEDRAPLEN e=60 cm INTERFERENCIA QUAVI | 9.5d | 2024-04-11 | 2024-04-22 | 1.07.178 FS+0.5d | 220.05d |
| 1.07.950 |  | PEDRAPLEN e=60 cm LIBERACIÓN PREDIAL LI | 0.5d | 2024-05-02 | 2024-05-02 | 1.07.910 FS+0.5d | 206.05d |
| 1.07.960 |  | PEDRAPLEN e=60 cm LIBERACIÓN PREDIAL LD | 31.5d | 2024-05-21 | 2024-06-27 | 1.07.911 | 70.55d |
|  | 5 | **PEDRAPLÉN e=30 cm** |  | 2023-12-30 | 2024-07-04 |  |  |
| 1.07.391 |  | PEDRAPLEN e=30 cm (A2-I-01) | 1.5d | 2023-12-30 | 2024-01-02 | 1.07.361 FS+0.5d | 314.05d |
| 1.07.392 |  | PEDRAPLEN e=30 cm (A2-I-02) | 7.5d | 2024-03-30 | 2024-04-08 | 1.07.362 FS+0.5d | 0d |
| 1.07.970 |  | PEDRAPLEN e=30 cm INTERFERENCIA SEDACHIMBOTE | 1.5d | 2024-04-09 | 2024-04-10 | 1.07.930 FS+0.5d | 211.05d |
| 1.07.980 |  | PEDRAPLEN e=30 cm INTERFERENCIA QUAVI | 1.5d | 2024-04-23 | 2024-04-24 | 1.07.940 FS+0.5d | 220.05d |
| 1.07.990 |  | PEDRAPLEN e=30 cm LIBERACIÓN PREDIAL LI | 0.5d | 2024-05-03 | 2024-05-03 | 1.07.950 FS+0.5d | 206.05d |
| 1.07.393 |  | PEDRAPLEN e=30 cm (A2-D-01) | 8.5d | 2024-06-07 | 2024-06-17 | 1.07.363 FS+0.5d | 23.05d |
| 1.07.991 |  | PEDRAPLEN e=30 cm LIBERACIÓN PREDIAL LD | 4.5d | 2024-06-27 | 2024-07-04 | 1.07.960 FS+0.5d | 70.55d |
|  | 6 | **CONFORMACIÓN DE CUERPO DE DIQUE CON MATERIAL PROPIO** |  | 2023-12-04 | 2024-08-07 |  |  |
| 1.07.452 |  | CONFORMACIÓN DE CUERPO DE DIQUE CON MATERIAL PROPIO (A2-I-01-B) | 0.5d | 2023-12-04 | 2023-12-04 | 1.07.331 FS+0.5d, A1050 SF | 45.55d |
| 1.07.453 |  | CONFORMACIÓN DE CUERPO DE DIQUE CON MATERIAL PROPIO (A2-I-03) | 1.5d | 2023-12-28 | 2023-12-29 | 1.07.332 FS+0.5d | 324.05d |
| 1.07.451 |  | CONFORMACIÓN DE CUERPO DE DIQUE CON MATERIAL PROPIO (A2-I-01) | 9.5d | 2024-01-03 | 2024-01-13 | 1.07.391 FS+0.5d | 314.05d |
| 1.07.456 |  | CONFORMACIÓN DE CUERPO DE DIQUE CON MATERIAL PROPIO (A2-D-02) | 0.5d | 2024-03-12 | 2024-03-12 | 1.07.334 FS+0.5d | 264.05d |
| 1.07.454 |  | CONFORMACIÓN DE CUERPO DE DIQUE CON MATERIAL PROPIO (A2-I-02) | 55.5d | 2024-04-09 | 2024-06-13 | 1.07.392 FS+0.5d | 0d |
| 1.07.457 |  | CONFORMACIÓN DE CUERPO DE DIQUE CON MATERIAL PROPIO INTERFERENCIA SEDACHIMBOTE | 9.5d | 2024-04-11 | 2024-04-22 | 1.07.970 FS+0.5d | 211.05d |
| 1.07.458 |  | CONFORMACIÓN DE CUERPO DE DIQUE CON MATERIAL PROPIO INTERFERENCIA QUAVI | 6.5d | 2024-04-25 | 2024-05-03 | 1.07.980 FS+0.5d | 220.05d |
| 1.07.461 |  | CONFORMACIÓN DE CUERPO DE RAMPA CON MATERIAL PROPIO | 2.5d | 2024-05-02 | 2024-05-04 | 1.07.800 FS+0.5d | 236.05d |
| 1.07.459 |  | CONFORMACIÓN DE CUERPO DE DIQUE CON MATERIAL PROPIO LIBERACIÓN PREDIAL LI | 2.5d | 2024-05-04 | 2024-05-07 | 1.07.990 FS+0.5d | 206.05d |
| 1.07.455 |  | CONFORMACIÓN DE CUERPO DE DIQUE CON MATERIAL PROPIO (A2-D-01) | 41.5d | 2024-06-18 | 2024-08-07 | 1.07.393 FS+0.5d | 23.05d |
| 1.07.460 |  | CONFORMACIÓN DE CUERPO DE DIQUE CON MATERIAL PROPIO LIBERACIÓN PREDIAL LD | 22.5d | 2024-07-04 | 2024-08-01 | 1.07.991 FS+0.5d | 70.55d |
|  | 7 | **CONFORMACIÓN DE RELLENO NO ESTRUCTURAL CON MATERIAL PROPIO** |  | 2024-01-15 | 2024-08-12 |  |  |
| 1.07.491 |  | CONFORMACIÓN DE RELLENO NO ESTRUCTURAL CON MATERIAL PROPIO (A2-I-01) | 1.5d | 2024-01-15 | 2024-01-16 | 1.07.451 FS+0.5d | 314.05d |
| 1.07.494 |  | CONFORMACIÓN DE RELLENO NO ESTRUCTURAL CON MATERIAL PROPIO INTERFERENCIA SEDACHIMBOTE | 0.5d | 2024-04-23 | 2024-04-23 | 1.07.457 FS+0.5d | 211.05d |
| 1.07.495 |  | CONFORMACIÓN DE RELLENO NO ESTRUCTURAL CON MATERIAL PROPIO INTERFERENCIA QUAVI | 0.5d | 2024-05-04 | 2024-05-04 | 1.07.458 FS+0.5d | 220.05d |
| 1.07.496 |  | CONFORMACIÓN DE RELLENO NO ESTRUCTURAL CON MATERIAL PROPIO LIBERACIÓN PREDIAL LI | 0.5d | 2024-05-08 | 2024-05-08 | 1.07.459 FS+0.5d | 206.05d |
| 1.07.492 |  | CONFORMACIÓN DE RELLENO NO ESTRUCTURAL CON MATERIAL PROPIO (A2-I-02) | 1.5d | 2024-06-14 | 2024-06-15 | 1.07.454 FS+0.5d | 0d |
| 1.07.497 |  | CONFORMACIÓN DE RELLENO NO ESTRUCTURAL CON MATERIAL PROPIO LIBERACIÓN PREDIAL LD | 1.5d | 2024-08-01 | 2024-08-03 | 1.07.460 FS+0.5d | 70.55d |
| 1.07.493 |  | CONFORMACIÓN DE RELLENO NO ESTRUCTURAL CON MATERIAL PROPIO (A2-D-01) | 3.5d | 2024-08-08 | 2024-08-12 | 1.07.455 FS+0.5d | 23.05d |
|  | 8 | **CONFORMACIÓN DE MATERIAL GRANULAR EN CORONA DE DIQUE** |  | 2023-12-19 | 2025-01-16 |  |  |

| ID | WBS | Task | Duration | Start | Finish | Predecessors | Total float |
| --- | --- | --- | --- | --- | --- | --- | --- |
| 1.07.552 |  | CONFORMACIÓN DE MATERIAL GRANULAR EN CORONA DE DIQUE (A2-I-01-B) | 1.5d | 2023-12-19 | 2023-12-20 | 1.07.682 FS+0.5d | 350.02d |
| 1.07.553 |  | CONFORMACIÓN DE MATERIAL GRANULAR EN CORONA DE DIQUE (A2-I-03) | 2.5d | 2024-01-19 | 2024-01-22 | 1.07.683 FS+0.5d | 324.05d |
| 1.07.551 |  | CONFORMACIÓN DE MATERIAL GRANULAR EN CORONA DE DIQUE (A2-I-01) | 2.5d | 2024-02-01 | 2024-02-03 | 1.07.681 FS+0.5d | 314.05d |
| 1.07.556 |  | CONFORMACIÓN DE MATERIAL GRANULAR EN CORONA DE DIQUE (A2-D-02) | 2.5d | 2024-04-01 | 2024-04-03 | 1.07.686 FS+0.5d | 264.05d |
| 1.07.561 |  | CONFORMACIÓN DE CORONA DE RAMPA | 2.5d | 2024-05-06 | 2024-05-08 | 1.07.461 FS+0.5d | 236.05d |
| 1.07.558 |  | CONFORMACIÓN DE MATERIAL GRANULAR EN CORONA DE DIQUE INTERFERENCIA QUAVI | 2.5d | 2024-05-23 | 2024-05-25 | 1.07.688 FS+0.5d | 220.05d |
| 1.07.557 |  | CONFORMACIÓN DE MATERIAL GRANULAR EN CORONA DE DIQUE INTERFERENCIA SEDACHIMBOTE | 4.5d | 2024-05-31 | 2024-06-05 | 1.07.687 FS+0.5d | 211.05d |
| 1.07.559 |  | CONFORMACIÓN DE MATERIAL GRANULAR EN CORONA DE DIQUE LIBERACIÓN PREDIAL LI | 3.5d | 2024-06-06 | 2024-06-10 | 1.07.689 FS+0.5d | 206.05d |
| 1.07.560 |  | CONFORMACIÓN DE MATERIAL GRANULAR EN CORONA DE DIQUE LIBERACIÓN PREDIAL LD | 12.5d | 2024-11-04 | 2024-11-19 | 1.07.690 FS+0.5d | 70.55d |
| 1.07.554 |  | CONFORMACIÓN DE MATERIAL GRANULAR EN CORONA DE DIQUE (A2-I-02) | 30.5d | 2024-12-10 | 2025-01-16 | 1.07.684 FS+0.5d | 0d |
| 1.07.555 |  | CONFORMACIÓN DE MATERIAL GRANULAR EN CORONA DE DIQUE (A2-D-01) | 17.5d | 2024-12-24 | 2025-01-15 | 1.07.685 FS+0.5d | 23.05d |
|  | 9 | **GEOTEXTIL NO TEJIDO 400 G/M2, INC. COLOCACIÓN** |  | 2023-12-07 | 2024-09-12 |  |  |
| 1.07.622 |  | GEOTEXTIL NO TEJIDO 400 G/M2, INC. COLOCACIÓN (A2-I-01-B) | 1.5d | 2023-12-07 | 2023-12-11 | 1.07.292 FS+0.5d | 45.55d |
| 1.07.623 |  | GEOTEXTIL NO TEJIDO 400 G/M2, INC. COLOCACIÓN (A2-I-03) | 1.5d | 2024-01-05 | 2024-01-06 | 1.07.293 FS+0.5d | 324.05d |
| 1.07.621 |  | GEOTEXTIL NO TEJIDO 400 G/M2, INC. COLOCACIÓN (A2-I-01) | 1.5d | 2024-01-20 | 2024-01-22 | 1.07.291 FS+0.5d | 314.05d |
| 1.07.626 |  | GEOTEXTIL NO TEJIDO 400 G/M2, INC. COLOCACIÓN (A2-D-02) | 1.5d | 2024-03-18 | 2024-03-19 | 1.07.296 FS+0.5d | 264.05d |
| 1.07.627 |  | GEOTEXTIL NO TEJIDO 400 G/M2, INC. COLOCACIÓN INTERFERENCIA SEDACHIMBOTE | 3.5d | 2024-05-02 | 2024-05-06 | 1.07.850 FS+0.5d | 211.05d |
| 1.07.628 |  | GEOTEXTIL NO TEJIDO 400 G/M2, INC. COLOCACIÓN INTERFERENCIA QUAVI | 1.5d | 2024-05-09 | 2024-05-10 | 1.07.860 FS+0.5d | 220.05d |
| 1.07.629 |  | GEOTEXTIL NO TEJIDO 400 G/M2, INC. COLOCACIÓN LIBERACIÓN PREDIAL LI | 2.5d | 2024-05-16 | 2024-05-18 | 1.07.870 FS+0.5d | 206.05d |
| 1.07.624 |  | GEOTEXTIL NO TEJIDO 400 G/M2, INC. COLOCACIÓN (A2-I-02) | 18.5d | 2024-07-04 | 2024-07-25 | 1.07.294 FS+0.5d | 0d |
| 1.07.630 |  | GEOTEXTIL NO TEJIDO 400 G/M2, INC. COLOCACIÓN LIBERACIÓN PREDIAL LD | 9.5d | 2024-08-14 | 2024-08-26 | 1.07.880 FS+0.5d | 70.55d |
| 1.07.625 |  | GEOTEXTIL NO TEJIDO 400 G/M2, INC. COLOCACIÓN (A2-D-01) | 13.5d | 2024-08-27 | 2024-09-12 | 1.07.295 FS+0.5d | 23.05d |
|  | 12 | **COLOCACION Y ACOMODO DE ROCA EN TALUD DE DIQUE** |  | 2023-12-16 | 2024-12-23 |  |  |
| 1.07.682 |  | COLOCACION Y ACOMODO DE ROCA EN TALUD DE DIQUE (A2-I-01-B) | 1.5d | 2023-12-16 | 2023-12-18 | 1.03.612 FS+0.5d | 350.02d |
| 1.07.683 |  | COLOCACION Y ACOMODO DE ROCA EN TALUD DE DIQUE (A2-I-03) | 5.5d | 2024-01-12 | 2024-01-18 | 1.03.613 FS+0.5d | 324.05d |
| 1.07.681 |  | COLOCACION Y ACOMODO DE ROCA EN TALUD DE DIQUE (A2-I-01) | 2.5d | 2024-01-29 | 2024-01-31 | 1.03.611 FS+0.5d | 314.05d |
| 1.07.686 |  | COLOCACION Y ACOMODO DE ROCA EN TALUD DE DIQUE (A2-D-02) | 4.5d | 2024-03-23 | 2024-03-30 | 1.03.617 FS+0.5d | 264.05d |
| 1.07.688 |  | COLOCACION Y ACOMODO DE ROCA EN TALUD DE DIQUE INTERFERENCIA QUAVI | 3.5d | 2024-05-18 | 2024-05-22 | 1.03.619 FS+0.5d | 220.05d |
| 1.07.687 |  | COLOCACION Y ACOMODO DE ROCA EN TALUD DE DIQUE INTERFERENCIA SEDACHIMBOTE | 8.5d | 2024-05-21 | 2024-05-30 | 1.03.618 FS+0.5d | 211.05d |
| 1.07.689 |  | COLOCACION Y ACOMODO DE ROCA EN TALUD DE DIQUE LIBERACIÓN PREDIAL LI | 8.5d | 2024-05-27 | 2024-06-05 | 1.03.620 FS+0.5d | 206.05d |
| 1.07.690 |  | COLOCACION Y ACOMODO DE ROCA EN TALUD DE DIQUE LIBERACIÓN PREDIAL LD | 26.5d | 2024-10-01 | 2024-11-04 | 1.03.621 FS+0.5d | 70.55d |
| 1.07.684 |  | COLOCACION Y ACOMODO DE ROCA EN TALUD DE DIQUE (A2-I-02) | 48.5d | 2024-10-12 | 2024-12-09 | 1.03.614 FS+0.5d | 0d |
| 1.07.685 |  | COLOCACION Y ACOMODO DE ROCA EN TALUD DE DIQUE (A2-D-01) | 35.5d | 2024-11-12 | 2024-12-23 | 1.03.616 FS+0.5d | 23.05d |
|  | 4 | **OBRAS DE ARTE** |  | 2024-08-28 | 2024-10-29 |  |  |
|  | 1 | **TOMAS O CAPTACIONES** |  | 2024-08-28 | 2024-10-01 |  |  |
|  | 1 | **MOVIMIENTO DE TIERRAS** |  | 2024-08-28 | 2024-10-01 |  |  |
| 1.08.01 |  | EXCAVACION ESTRUCTURAL PARA OBRAS DE ARTE | 14.5d | 2024-08-28 | 2024-09-14 | 1.07.180 FS+83.5d | 8.81d |
| 1.08.02 |  | RELLENO ESTRUCTURAL PARA OBRAS DE ARTE CON MATERIAL PROPIO | 13.5d | 2024-09-16 | 2024-10-01 | 1.08.01 FS+0.5d | 8.81d |
|  | 2 | **CANALES** |  | 2024-09-16 | 2024-10-11 |  |  |
|  | 1 | **MOVIMIENTO DE TIERRAS** |  | 2024-09-16 | 2024-10-11 |  |  |
| 1.08.03 |  | EXCAVACION ESTRUCTURAL PARA OBRAS DE ARTE | 7.5d | 2024-09-16 | 2024-09-24 | 1.08.01 FS+0.53d | 47.83d |
| 1.08.04 |  | RELLENO ESTRUCTURAL PARA OBRAS DE ARTE CON MATERIAL PROPIO | 7.5d | 2024-10-02 | 2024-10-11 | 1.08.02 FS+0.5d | 72.99d |
|  | 3 | **OBRAS DE DESCARGA** |  | 2024-09-25 | 2024-09-26 |  |  |
|  | 1 | **MOVIMIENTO DE TIERRAS** |  | 2024-09-25 | 2024-09-26 |  |  |
| 1.08.05 |  | EXCAVACION ESTRUCTURAL PARA OBRAS DE ARTE | 1.5d | 2024-09-25 | 2024-09-26 | 1.08.03 FS+0.5d | 47.83d |
|  | 4 | **RETORNOS TIPO A2-OA-RE-I-11-25** |  | 2024-09-27 | 2024-10-16 |  |  |
|  | 1 | **MOVIMIENTO DE TIERRAS** |  | 2024-09-27 | 2024-10-16 |  |  |
| 1.08.07 |  | EXCAVACION ESTRUCTURAL PARA OBRAS DE ARTE | 1.5d | 2024-09-27 | 2024-09-28 | 1.08.05 FS+0.5d | 47.83d |
| 1.08.08 |  | RELLENO ESTRUCTURAL PARA OBRAS DE ARTE CON MATERIAL PROPIO | 3.76d | 2024-10-12 | 2024-10-16 | 1.08.04 FS+0.5d | 76.78d |
|  | 5 | **RETORNOS Q=100 A 1000 l/s** |  | 2024-09-30 | 2024-10-29 |  |  |
|  | 1 | **MOVIMIENTO DE TIERRAS** |  | 2024-09-30 | 2024-10-29 |  |  |
| 1.08.09 |  | EXCAVACIÓN ESTRUCTURAL PARA OBRAS DE ARTE | 9.5d | 2024-09-30 | 2024-10-11 | 1.08.07 FS+0.5d | 47.83d |
| 1.08.10 |  | CAMA DE ARENA | 1.5d | 2024-10-12 | 2024-10-14 | 1.08.09 FS+0.5d | 51.33d |
| 1.08.11 |  | RELLENO ESTRUCTURAL PARA OBRAS DE ARTE CON MATERIAL PROPIO | 14.5d | 2024-10-12 | 2024-10-29 | 1.08.09 FS+0.5d | 47.83d |
|  | 6 | **INTERFERENCIAS** |  | 2024-09-17 | 2024-10-26 |  |  |
|  | 3 | **REPOSICION DE ESTRUCTURAS (PASE DE AGUA)** |  | 2024-10-12 | 2024-10-18 |  |  |
| 1.09.01 |  | DEMOLICIÓN DE ESTRUCTURAS EXISTENTES | 0.53d | 2024-10-12 | 2024-10-12 | 1.08.09 FS+0.53d | 81.66d |
| 1.09.02 |  | REPOSICIÓN DE PASE DE AGUA TUBERÍA HDPE Ø=36" | 0.53d | 2024-10-14 | 2024-10-14 | 1.09.01 FS+0.48d | 93.75d |
| 1.09.03 |  | REPOSICIÓN DE PASE DE AGUA TUBERÍA HDPE Ø=24" | 0.53d | 2024-10-15 | 2024-10-15 | 1.09.02 FS+0.53d | 93.75d |
| 1.09.05 |  | SUMINISTRO Y MONTAJE DE PANELES DE C°A° 1.9mx1.0mx0.20m EN PASE DE AGUA | 0.53d | 2024-10-16 | 2024-10-16 | 1.09.03 FS+0.5d | 93.75d |
| 1.09.06 |  | SUMINISTRO Y MONTAJE DE PANELES DE C°A° 1.6mx1.0mx0.20m EN PASE DE AGUA | 0.53d | 2024-10-17 | 2024-10-17 | 1.09.05 SS+1.06d | 93.75d |
| 1.09.07 |  | SUMINISTRO Y MONTAJE DE PANELES DE C°A° 1.8mx1.0mx0.20m EN PASE DE AGUA | 0.53d | 2024-10-18 | 2024-10-18 | 1.09.06 FS+0.53d | 93.75d |
|  | 4 | **CABEZAL DE ENTRADA Y SALIDA (PASE DE AGUA)** |  | 2024-10-19 | 2024-10-25 |  |  |
| 1.09.10 |  | ENCOFRADO Y DESENCOFRADO NORMAL | 4.5d | 2024-10-19 | 2024-10-24 | 1.09.07 FS+0.5d | 93.75d |
| 1.09.09 |  | CONCRETO 175 Kg/Cm2 | 0.5d | 2024-10-25 | 2024-10-25 | 1.09.10 FS+0.5d | 93.75d |
|  | 5 | **CRUCE VEHICULAR (PASE DE AGUA)** |  | 2024-09-17 | 2024-10-01 |  |  |
| 1.09.14 |  | ACERO DE REFUERZO fy=4200 kg/cm2 | 3.5d | 2024-09-17 | 2024-09-20 | 1.08.03 SS+1.2d | 113.64d |
| 1.09.13 |  | ENCOFRADO Y DESENCOFRADO NORMAL | 5.5d | 2024-09-21 | 2024-09-27 | 1.09.14 FS+0.5d | 113.64d |
| 1.09.11 |  | CONCRETO f'c=280 kg/cm2 | 0.5d | 2024-09-28 | 2024-09-28 | 1.09.13 FS+0.5d | 113.64d |
| 1.09.12 |  | CONCRETO CICLÓPEO F´C=170 Kg/cm2 | 0.59d | 2024-09-30 | 2024-09-30 | 1.09.11 FS+0.53d | 113.64d |

| ID | WBS | Task | Duration | Start | Finish | Predecessors | Total float |
| --- | --- | --- | --- | --- | --- | --- | --- |
| 1.09.15 |  | MONTAJE DE LOSA PREFABRICADA | 0.53d | 2024-10-01 | 2024-10-01 | 1.09.12 FS+0.53d | 113.64d |
|  | 6 | **REPOSICION DE CANALES** |  | 2024-10-14 | 2024-10-26 |  |  |
|  | 1 | **MOVIMIENTO DE TIERRAS** |  | 2024-10-14 | 2024-10-26 |  |  |
| 1.09.16 |  | DEMOLICION DE ESTRUCTURAS EXISTENTES | 8.5d | 2024-10-14 | 2024-10-23 | 1.09.01 FS+0.5d | 81.66d |
| 1.09.17 |  | EXCAVACIÓN EN TERRENO NATURAL CON EQUIPO | 0.53d | 2024-10-24 | 2024-10-24 | 1.09.16 FS+0.53d | 81.66d |
| 1.09.18 |  | RELLENO ESTRUCTURAL PARA OBRAS DE ARTE CON MATERIAL PROPIO | 1.06d | 2024-10-25 | 2024-10-26 | 1.09.17 FS+0.53d | 93.31d |
|  | 5 | **TRANSPORTE DE MATERIAL** |  | 2023-11-28 | 2025-01-16 |  |  |
| 1.09.21 |  | TRANSPORTE DE MATERIAL EXCEDENTE | 276.59d | 2023-11-28 | 2024-10-28 | 1.07.100 SS | 90.96d |
| 1.09.20 |  | TRANSPORTE DE ROCA | 314d | 2023-12-11 | 2024-12-23 | 1.03.612 SS-1d, 1.07.685 FF | 45.05d |
| 1.09.19 |  | TRANSPORTE DE MATERIAL GRANULAR | 331.5d | 2023-12-13 | 2025-01-16 | 1.07.361 SS+0.2d, 1.07.554 FF | 25.81d |
|  | 7 | **ARQUITECTURA Y PAISAJISMO** |  | 2024-10-25 | 2024-11-09 |  |  |
|  | 1 | **MOVIMIENTO DE TIERRAS** |  | 2024-10-25 | 2024-10-29 |  |  |
| 1.09.22 |  | EXCAVACIÓN MANUAL PARA INSTALACIÓN DE BORDILLOS Y CIMENTACIONES | 1.5d | 2024-10-25 | 2024-10-26 | 1.09.17 FS+0.5d | 81.66d |
| 1.09.23 |  | EXCAVACIÓN PARA MEJORAMIENTO DE SUELO CON TIERRA VEGETAL | 0.5d | 2024-10-28 | 2024-10-28 | 1.09.22 FS+0.5d, 1.09.21 FF | 90.9d |
| 1.09.24 |  | ELIMINACION DE MATERIAL EXCEDENTE (DME´S) | 0.5d | 2024-10-29 | 2024-10-29 | 1.09.23 FS+0.5d | 90.9d |
|  | 2 | **PAVIMENTOS, RECUBRIMIENTOS Y BORDILLOS** |  | 2024-10-28 | 2024-11-09 |  |  |
| 1.09.27 |  | BORDILLOS DE PIEDRA DEL LUGAR | 2.65d | 2024-10-28 | 2024-10-30 | 1.09.22 FS+0.53d | 81.66d |
| 1.09.25 |  | PISO DE GRAVILLA | 0.53d | 2024-10-31 | 2024-10-31 | 1.09.27 FS+0.53d | 81.66d |
| 1.09.26 |  | RECUBRIMIENTO DE PIEDRA DEL LUGAR e=0.05cm | 6.5d | 2024-11-02 | 2024-11-09 | 1.09.25 FS+0.5d | 81.66d |
|  | 8 | **PROGRAMA DE CIERRE DE OBRA** |  | 2023-11-28 | 2025-02-15 |  |  |
| 01.10.01 |  | ACONDICIONAMIENTO DE DEPÓSITOS DE MATERIALES EXCEDENTES (DME) | 333.5d | 2023-11-28 | 2025-01-06 | A1040 SS-0.4d | 34.67d |
| 01.10.02 |  | RESTAURACIÓN DE ÁREAS DE INSTALACIONES PROVISIONALES | 6.41d | 2025-01-30 | 2025-02-07 | 1.07.234 FS+8d | 0d |
| 01.10.03 |  | DESMOVILIZACIÓN DE EQUIPOS | 5.9d | 2025-02-08 | 2025-02-15 | 1.09.26 FF, 1.07.232 FF, 1.07.233 FF, 1.07.235 FF, 1.07.236 FF, 1.07.810 FF, 1.07.820 FF, 1.07.830 FF, 1.07.840 FF, 1.01.03 FF, 1.05.08 FF, 1.04.47 FF, 1.07.561 FF, 01.02.02 FF, 01.10.02 FS+1.5d, 01.10.01 FF, 1.04.03 FF, 1.04.09 FF, 1.04.12 FF, 1.04.29 FF, 1.04.34 FF, 1.04.39 FF, 1.04.41 FF, 1.04.15 FF, 1.05.01, 1.05.02 FF, 1.06.02 FF, 1.06.03 FF, 1.07.01 FF, 1.07.04 FF, 1.07.551 FF, 1.09.09 FF, 1.09.15 FF, 1.09.18 FF, 1.09.19 FF, 1.09.20 FF, 1.09.24 FF | 0d |

## Version 2 (data date 2023-11-23, saved 2023-10-20, file A2 TRAMO I.xer)

Last finish stays 2025-02-15.

Added:

| ID | Task | Duration | Start | Finish | Predecessors | Resources |
| --- | --- | --- | --- | --- | --- | --- |
| 1.01.01 | CARTEL DE IDENTIFICACIÓN OBRA 4.80 x 3.60 m. | 0.5d | 2023-11-28 | 2023-11-29 | 1.01.02 SS | CAPATAZ; OPERARIO; PEON |
| 1.03.01 | COLOCACION Y ACOMODO DE ROCA EN UÑA DE DIQUE | 7.33d | 2023-12-30 | 2024-01-10 | 1.07.57 FS+1.4d | CAPATAZ [259.47 h]; OPERARIO [259.47 h]; PEON [1298.19 h]; Excavadora Sobre Oruga 260 HP [389.41 h] |
| 2 | **DIQUE DE TIERRA COMPACTADA A2-D-01** |  | 2024-04-08 | 2024-07-12 |  |  |
| 1.03.02 | COLOCACION Y ACOMODO DE ROCA EN UÑA DE DIQUE | 76.67d | 2024-04-08 | 2024-07-12 | 1.07.58 FS+0.5d | CAPATAZ [2561.2 h]; OPERARIO [2561.2 h]; PEON [2561.2 h]; Excavadora Sobre Oruga 260 HP [3843.89 h] |
| 3 | **DIQUE DE TIERRA COMPACTADA A1-I-03** |  | 2024-01-10 | 2024-01-18 |  |  |
| 1.03.03 | COLOCACION Y ACOMODO DE ROCA EN UÑA DE DIQUE | 6d | 2024-01-10 | 2024-01-18 | 1.07.59 FS+1d | CAPATAZ [255.11 h]; OPERARIO [255.11 h]; PEON [1276.37 h]; Excavadora Sobre Oruga 260 HP [382.87 h] |
| 4 | **DIQUE DE TIERRA COMPACTADA A1-I-02** |  | 2024-07-23 | 2024-10-17 |  |  |
| 1.03.04 | COLOCACION Y ACOMODO DE ROCA EN UÑA DE DIQUE | 67.33d | 2024-07-23 | 2024-10-17 | 1.07.60 FS+1d | CAPATAZ [2281.92 h]; OPERARIO [2281.92 h]; PEON [11417 h]; Excavadora Sobre Oruga 260 HP [3424.74 h] |
| 5 | **DIQUE DE TIERRA COMPACTADA A2-I-01-B** |  | 2024-03-14 | 2024-03-18 |  |  |
| 1.03.05 | COLOCACION Y ACOMODO DE ROCA EN UÑA DE DIQUE | 2.78d | 2024-03-14 | 2024-03-18 | 1.07.61 FS+1d | CAPATAZ [113.47 h]; OPERARIO [113.47 h]; PEON [567.73 h]; Excavadora Sobre Oruga 260 HP [170.3 h] |
| 6 | **DIQUE DE TIERRA COMPACTADA A1-I-01** |  | 2024-05-10 | 2024-05-16 |  |  |
| 1.03.06 | COLOCACION Y ACOMODO DE ROCA EN UÑA DE DIQUE | 5d | 2024-05-10 | 2024-05-16 | 1.07.62 FS+1d | CAPATAZ [176.61 h]; OPERARIO [176.61 h]; PEON [883.61 h]; Excavadora Sobre Oruga 260 HP [265.05 h] |
| 1.04.18 | RELLENO COMÚN PARA ZANJAS | 0d | 2024-12-17 | 2024-12-17 | 1.04.15 SS |  |
| 1.04.19 | CONCRETO f'c=100 kg/cm2 (buzones) | 0d | 2024-12-17 | 2024-12-17 | 1.04.15 SS | CAPATAZ; OPERARIO; PEON; OFICIAL |
| 1.07.23 | PERFILADO Y COMPACTACIÓN EN ZONA DE CORTE EN CORONA (A2-I-01) | 0d | 2024-05-27 | 2024-05-27 | 1.07.55 FS+1d | CAPATAZ; Excavadora Sobre Oruga 260 HP; PEON; Rodillo Vib. Liso Autopropulsado 135 HP 12 TM; Motoniveladora 185 HP; Camión Cisterna 4x2 400 HP Agua (5000 gal) |
| 1.07.35 | Pedraplén e=60 cm (A2-I-02) | 16d | 2024-03-12 | 2024-04-03 | 1.07.32 FS+1d | CAPATAZ [27.79 h]; OPERARIO [274.85 h]; PEON [2745.41 h]; OFICIAL [274.85 h]; CARGADOR SOBRE LLANTAS DE 200-250 HP [274.85 h]; Excavadora Sobre Oruga 320 [275 h] |
| 1.08.06 | RELLENO ESTRUCTURAL PARA OBRAS DE ARTE CON MATERIAL PROPIO | 0d | 2024-11-13 | 2024-11-13 | 1.08.05 FS+1d | Camión Cisterna 4x2 400 HP Agua (5000 gal); CAPATAZ; OPERARIO; PEON; Rodillo Vib. Liso Autopropulsado 135 HP 12 TM; Tractor S/Orugas (D6T) - 180 HP |
| 1.09.04 | REPOSICIÓN DE PASE DE AGUA TUBERÍA HDPE Ø=18" | 0d | 2024-11-29 | 2024-11-29 | 1.09.03 | CAPATAZ; OPERARIO; PEON; Retroexcavador 58 HP |
| 1.09.08 | REPARACIÓN DE CONCRETO | 0d | 2024-12-03 | 2024-12-03 | 1.09.07 | CAPATAZ; CUADRADOR/VIGÍA; OPERARIO; PEON; Excavadora + Martillo hidraúlico |

Removed: A1010 BUENA PRO; A1020 KICK OF MEETING (KMO); INICIO DE PLAZO CONTRACTUAL - FIN DE OBRA; A1070 INICIO DE DIQUE MARGEN IZQUIERDA; A1110 INICIO DE DIQUE MARGEN DERECHA; A1130 INICIO DE DIQUE INTERFERENCIAS; A1150 INICIO DE DIQUE LIBERACIÓN PREDIAL; A1230 FIN DE DIQUE INTERFERENCIAS; A1260 FIN DE DIQUE LIBERACIÓN PREDIAL; A1210 FIN DE DIQUE MARGEN DERECHA; A1200 FIN DE DIQUE MARGEN IZQUIERDA; 1.03.612 COLOCACION Y ACOMODO DE ROCA EN UÑA DE DIQUE A2-I-01-B; 1.03.613 COLOCACION Y ACOMODO DE ROCA EN UÑA DE DIQUE A2-I-03; 1.03.611 COLOCACION Y ACOMODO DE ROCA EN UÑA DE DIQUE A2-I-01; 1.03.617 COLOCACION Y ACOMODO DE ROCA EN UÑA DE DIQUE A2-D-02; 1.03.618 COLOCACION Y ACOMODO DE ROCA EN UÑA DE DIQUE INTERFERENCIA SEDACHIMBOTE; 1.03.619 COLOCACION Y ACOMODO DE ROCA EN UÑA DE DIQUE INTERFERENCIA QUAVI; 1.03.620 COLOCACION Y ACOMODO DE ROCA EN UÑA DE DIQUE LIBERACIÓN PREDIAL LI; 1.03.614 COLOCACION Y ACOMODO DE ROCA EN UÑA DE DIQUE A2-I-02; 1.03.621 COLOCACION Y ACOMODO DE ROCA EN UÑA DE DIQUE LIBERACIÓN PREDIAL LD; 1.03.616 COLOCACION Y ACOMODO DE ROCA EN UÑA DE DIQUE A2-D-01; 1.07.710 EXCAVACIÓN INTERFERENCIA SEDACHIMBOTE; 1.07.750 EXCAVACIÓN LIBERACIÓN PREDIAL LD; 1.07.720 EXCAVACIÓN INTERFERENCIA QUAVI; 1.07.730 EXCAVACIÓN LIBERACIÓN PREDIAL LI; 1.07.177 EXCAVACIÓN DE UÑA CON EQUIPO INTERFERENCIA SEDACHIMBOTE; 1.07.178 EXCAVACIÓN DE UÑA CON EQUIPO INTERFERENCIA QUAVI; 1.07.179 EXCAVACIÓN DE UÑA CON EQUIPO LIBERACIÓN PREDIAL LI; 1.07.180 EXCAVACIÓN DE UÑA CON EQUIPO LIBERACIÓN PREDIAL LD; 1.07.820 PERFILADO Y COMPACTACIÓN EN ZONA DE CORTE EN CORONA INTERFERENCIA QUAVI; 1.07.810 PERFILADO Y COMPACTACIÓN EN ZONA DE CORTE EN CORONA INTERFERENCIA SEDACHIMBOTE; 1.07.830 PERFILADO Y COMPACTACIÓN EN ZONA DE CORTE EN CORONA LIBERACIÓN PREDIAL LI; 1.07.840 PERFILADO Y COMPACTACIÓN EN ZONA DE CORTE EN CORONA LIBERACIÓN PREDIAL LD; 1.07.850 PERFILADO EN ZONA DE CORTE DE TALUD DE DIQUE INTERFERENCIA SEDACHIMBOTE; 1.07.860 PERFILADO EN ZONA DE CORTE DE TALUD DE DIQUE QUAVI; 1.07.870 PERFILADO EN ZONA DE CORTE DE TALUD DE DIQUE LIBERACIÓN PREDIAL LI; 1.07.880 PERFILADO EN ZONA DE CORTE DE TALUD DE DIQUE LIBERACIÓN PREDIAL LD; 1.07.890 PREPARACIÓN DE FUNDACIÓN DE CUERPO DE DIQUE INTERFERENCIA SEDACHIMBOTE; 1.07.910 PREPARACIÓN DE FUNDACIÓN DE CUERPO DE DIQUE LIBERACIÓN PREDIAL LI; 1.07.911 PREPARACIÓN DE FUNDACIÓN DE CUERPO DE DIQUE LIBERACIÓN PREDIAL LD; 1.07.362 PEDRAPLÉN e=60 cm (A2-I-02); 1.07.930 PEDRAPLEN e=60 cm INTERFERENCIA SEDACHIMBOTE; 1.07.940 PEDRAPLEN e=60 cm INTERFERENCIA QUAVI; 1.07.950 PEDRAPLEN e=60 cm LIBERACIÓN PREDIAL LI; 1.07.960 PEDRAPLEN e=60 cm LIBERACIÓN PREDIAL LD; 1.07.970 PEDRAPLEN e=30 cm INTERFERENCIA SEDACHIMBOTE; 1.07.980 PEDRAPLEN e=30 cm INTERFERENCIA QUAVI; 1.07.990 PEDRAPLEN e=30 cm LIBERACIÓN PREDIAL LI; 1.07.991 PEDRAPLEN e=30 cm LIBERACIÓN PREDIAL LD; 1.07.457 CONFORMACIÓN DE CUERPO DE DIQUE CON MATERIAL PROPIO INTERFERENCIA SEDACHIMBOTE; 1.07.458 CONFORMACIÓN DE CUERPO DE DIQUE CON MATERIAL PROPIO INTERFERENCIA QUAVI; 1.07.459 CONFORMACIÓN DE CUERPO DE DIQUE CON MATERIAL PROPIO LIBERACIÓN PREDIAL LI; 1.07.460 CONFORMACIÓN DE CUERPO DE DIQUE CON MATERIAL PROPIO LIBERACIÓN PREDIAL LD; 1.07.494 CONFORMACIÓN DE RELLENO NO ESTRUCTURAL CON MATERIAL PROPIO INTERFERENCIA SEDACHIMBOTE; 1.07.495 CONFORMACIÓN DE RELLENO NO ESTRUCTURAL CON MATERIAL PROPIO INTERFERENCIA QUAVI; 1.07.496 CONFORMACIÓN DE RELLENO NO ESTRUCTURAL CON MATERIAL PROPIO LIBERACIÓN PREDIAL LI; 1.07.497 CONFORMACIÓN DE RELLENO NO ESTRUCTURAL CON MATERIAL PROPIO LIBERACIÓN PREDIAL LD; 1.07.558 CONFORMACIÓN DE MATERIAL GRANULAR EN CORONA DE DIQUE INTERFERENCIA QUAVI; 1.07.557 CONFORMACIÓN DE MATERIAL GRANULAR EN CORONA DE DIQUE INTERFERENCIA SEDACHIMBOTE; 1.07.559 CONFORMACIÓN DE MATERIAL GRANULAR EN CORONA DE DIQUE LIBERACIÓN PREDIAL LI; 1.07.560 CONFORMACIÓN DE MATERIAL GRANULAR EN CORONA DE DIQUE LIBERACIÓN PREDIAL LD; 1.07.627 GEOTEXTIL NO TEJIDO 400 G/M2, INC. COLOCACIÓN INTERFERENCIA SEDACHIMBOTE; 1.07.628 GEOTEXTIL NO TEJIDO 400 G/M2, INC. COLOCACIÓN INTERFERENCIA QUAVI; 1.07.629 GEOTEXTIL NO TEJIDO 400 G/M2, INC. COLOCACIÓN LIBERACIÓN PREDIAL LI; 1.07.630 GEOTEXTIL NO TEJIDO 400 G/M2, INC. COLOCACIÓN LIBERACIÓN PREDIAL LD; 1.07.688 COLOCACION Y ACOMODO DE ROCA EN TALUD DE DIQUE INTERFERENCIA QUAVI; 1.07.687 COLOCACION Y ACOMODO DE ROCA EN TALUD DE DIQUE INTERFERENCIA SEDACHIMBOTE; 1.07.689 COLOCACION Y ACOMODO DE ROCA EN TALUD DE DIQUE LIBERACIÓN PREDIAL LI; 1.07.690 COLOCACION Y ACOMODO DE ROCA EN TALUD DE DIQUE LIBERACIÓN PREDIAL LD

Changed:

| ID | Task | Start | Finish | Duration | Total float | Predecessors | Other |
| --- | --- | --- | --- | --- | --- | --- | --- |
| 1 | **HITOS** | 2023-11-06 → 2023-11-24 (+18d) | 2023-11-09 → 2025-02-15 (+464d) |  |  |  |  |
| A1030 | INICIO DEL PLAZO CONTRACTUAL - ACCESO AL SITIO |  |  |  |  | KICK OF MEETING (KMO) SS+14.5d → none |  |
| A1040 | INICIO DE EXCAVACIÓN |  |  |  | 44.65d → 424.62d | A1030 SS+4.4d → A1030 SS+4d |  |
| A1050 | INICIO DE RELLENO DE DIQUE | 2023-12-04 → 2023-12-19 (+15d) | 2023-12-04 → 2023-12-19 (+15d) |  | 57.75d → 424.62d | A1040 SS+5.5d → A1040 SS+21d |  |
| A1060 | FIN DE OBRA |  |  |  | 0d → 0.1d | 01.10.03 FF+0.3d → 01.10.03 FF-0.09d |  |
| 1 | **SUBPROYECTO A2 TRAMO I (OPCIÓN A)** |  | 2025-02-08 → 2025-02-07 (-1d) |  |  |  |  |
| 1 | **DEFENSAS RIBEREÑAS** |  | 2025-02-08 → 2025-02-07 (-1d) |  |  |  |  |
| 1 | **OBRAS PRELIMINARES** |  | 2025-02-05 → 2025-02-07 (+2d) |  |  |  |  |
| 1.01.02 | INSTALACIONES PROVISIONALES PARA LA OBRA |  | 2023-11-28 → 2023-12-05 (+7d) | 0.5d → 5d | 8.68d → 7d | 01.02.01 FS-10.4d → A1030 SS+5d |  |
| 1.01.03 | MANTENIMIENTO DE TRÁNSITO Y SEGURIDAD VIAL |  | 2025-02-05 → 2025-02-07 (+2d) | 359.5d → 340.67d | 8.68d → 7d | 1.01.02 SS → 1.01.02 SS, 01.02.01 SS, 1.01.01 SS |  |
| 2 | **TRABAJOS PRELIMINARES** |  | 2025-02-08 → 2025-02-07 (-1d) |  |  |  |  |
| 01.02.01 | MOVILIZACION Y DESMOVILIZACIÓN DE EQUIPOS |  | 2023-12-12 → 2023-12-13 (+1d) | 13.76d → 13.4d |  | A1030 SS-0.4d → A1030 SS | was named MOVILIZACIÓN DE EQUIPOS; resources AYUDANTE DE NIVELADOR [9485 h]; AYUDANTE DE TOPOGRAFO [9485 h]; TOPOGRAFO [6323.2 h]; OP. NIVELADOR [3161.6 h] → Camión baranda 3 TON [2 h]; Camión Cisterna 4x2 400 HP Agua (5000 gal) [3 h]; Camión grua [1 h]; Camión Plataforma 4x2 122 HP [1 h]; Camión Volquete (15 m3) [20 h]; Cargador Frontal 195 HP [2 h]; CARGADOR SOBRE LLANTAS DE 200-250 HP [2 h]; Excavadora Sobre Oruga 260 HP [11 h]; Motoniveladora 185 HP [4 h]; Retroexcavador 58 HP [3 h]; Rodillo Vib. Liso Autopropulsado 135 HP 12 TM [4 h]; Tractor S/Orugas (D6T) - 180 HP [5 h]; Camión Volquete Roquero (15 m3) [10 h] |
| 01.02.02 | TOPOGRAFÍA Y GEOREFERENCIACIÓN |  | 2025-02-08 → 2025-02-07 (-1d) | 362.5d → 340.67d | 5.67d → 7d | A1030 SS+4d → 1.01.01 SS, 1.07.05 SS, 1.01.02 SS, 1.01.03 SS |  |
| 3 | **DIQUES DE TIERRA COMPACTADA CON ENROCADO** | 2023-12-12 → 2023-12-30 (+18d) | 2024-11-11 → 2024-10-17 (-25d) |  |  |  |  |
| 1 | **DIQUE DE TIERRA COMPACTADA A2-D-02** | 2023-12-12 → 2023-12-30 (+18d) | 2024-11-11 → 2024-01-10 (-306d) |  |  |  | was named COLOCACION Y ACOMODO DE ROCA EN UÑA DE DIQUE |
| 4 | **OBRAS DE ARTE (TOMAS Y RETORNOS)** | 2024-08-28 → 2024-10-14 (+47d) | 2025-02-05 → 2025-01-23 (-13d) |  |  |  |  |
| 1 | **TOMAS O CAPTACIONES** | 2024-08-28 → 2024-10-14 (+47d) | 2025-02-05 → 2025-01-17 (-19d) |  |  |  |  |
| 1 | **OBRAS DE CONCRETO** | 2024-10-02 → 2024-11-08 (+37d) | 2025-02-03 → 2025-01-13 (-21d) |  |  |  |  |
| 1.04.01 | CONCRETO f'c=100 kg/cm2 | 2024-10-02 → 2024-11-08 (+37d) | 2024-10-02 → 2024-11-08 (+37d) | 0.53d → 0.5d | 8.81d → 24.07d | 1.08.02 FS+0.5d → 1.08.02 FS+1.5d |  |
| 1.04.05 | ACERO DE REFUERZO fy=4200 kg/cm2 | 2024-10-03 → 2024-11-09 (+37d) | 2024-12-03 → 2025-01-09 (+37d) | 50.65d → 47.83d | 8.81d → 24.07d | 1.04.01 FS+0.53d → 1.04.01 FS+0.5d |  |
| 1.04.04 | ENCOFRADO Y DESENCOFRADO RECTO | 2024-12-04 → 2024-11-27 (-7d) | 2025-01-17 → 2025-01-10 (-7d) | 36.5d → 34d | 8.81d → 24.07d | 1.04.05 FS+0.5d → 1.04.05 FS-33d |  |
| 1.04.02 | CONCRETO f'c=280 kg/cm2 | 2025-01-18 → 2025-01-02 (-16d) | 2025-01-29 → 2025-01-13 (-16d) | 9.5d → 8.33d | 8.81d → 24.07d | 1.04.04 FS+0.5d → 1.04.04 FS-7d |  |
| 1.04.03 | CONCRETO CICLÓPEO f'c=280 kg/cm2 + 30% P.G. | 2025-01-30 → 2025-01-09 (-21d) | 2025-02-03 → 2025-01-13 (-21d) | 3.5d → 2.67d | 10.84d → 27.44d | 1.04.02 FS+0.5d → 1.04.04 FS-1d |  |
| 3 | **ESTRUCTURAS METÁLICAS** | 2025-01-30 → 2025-01-13 (-17d) | 2025-02-05 → 2025-01-17 (-19d) |  |  |  |  |
| 1.04.06 | COMPUERTA METALICA PLANA DESLIZANTE DE 1.0x1.0 m | 2025-01-30 → 2025-01-13 (-17d) | 2025-02-01 → 2025-01-15 (-17d) | 2.5d → 2d | 8.81d → 24.07d | 1.04.02 FS+0.5d → 1.04.02 FS-0.5d |  |
| 1.04.07 | COMPUERTA METALICA PLANA DESLIZANTE DE 1.5x1.0 m | 2025-01-30 → 2025-01-13 (-17d) | 2025-01-31 → 2025-01-13 (-18d) | 0.53d → 0.5d | 12.23d → 27.78d | 1.04.06 FS-2d → 1.04.06 SS |  |
| 1.04.10 | BARANDA DE FIERRO GALVANIZADO 1 1/2" | 2025-01-30 → 2025-01-13 (-17d) | 2025-01-30 → 2025-01-13 (-17d) | 0.53d → 0.5d | 8.81d → 27.78d |  |  |
| 1.04.08 | REJILLA METÁLICA DE 1.00x1.00m | 2025-01-31 → 2025-01-14 (-17d) | 2025-02-01 → 2025-01-14 (-18d) | 0.53d → 0.5d | 12.23d → 24.07d | 1.04.07 FS+0.5d → 1.04.06 SS+1.1d |  |
| 1.04.09 | REJILLA METÁLICA DE 1.50x1.00m | 2025-01-31 → 2025-01-14 (-17d) | 2025-02-01 → 2025-01-15 (-17d) |  | 12.23d → 24.07d | 1.04.08 FS-0.45d → 1.04.08 SS+0.5d |  |
| 1.04.11 | ESCALERA TIPO GATO | 2025-02-01 → 2025-01-15 (-17d) | 2025-02-03 → 2025-01-16 (-18d) | 1.5d → 1d | 8.81d → 24.07d | 1.04.10 FS+1.5d → 1.04.09 FS+0.5d |  |
| 1.04.12 | TAPA DE CONCRETO | 2025-02-04 → 2025-01-16 (-19d) | 2025-02-05 → 2025-01-17 (-19d) | 1.5d → 0.61d | 8.81d → 24.07d | 1.04.11 FS+0.5d → 1.04.11 |  |
| 2 | **TUBERÍAS** | 2024-08-28 → 2024-10-14 (+47d) | 2024-11-14 → 2024-12-23 (+39d) |  |  |  |  |
| 1.04.13 | EXCAVACIÓN ESTRUCTURAL PARA OBRAS DE ARTE (buzones) | 2024-08-28 → 2024-10-14 (+47d) | 2024-08-29 → 2024-10-15 (+47d) | 1.5d → 2d | 77.85d → 42.5d | 1.08.01 SS+0.2d → 1.08.01 SS |  |
| 1.04.14 | EXCAVACIÓN DE ZANJA | 2024-08-31 → 2024-10-16 (+46d) | 2024-09-18 → 2024-11-04 (+47d) | 15.5d → 13.67d | 77.85d → 42.5d |  |  |
| 1.04.16 | CAMA DE ARENA | 2024-09-19 → 2024-11-05 (+47d) | 2024-09-21 → 2024-11-07 (+47d) | 2.5d → 2d | 77.85d → 42.5d | 1.04.14 FS+0.5d → 1.04.14 FS+1d |  |
| 1.04.24 | SUMINISTRO E INSTALACIÓN DE TUBERÍA GRP DN600 mm SN2500 | 2024-09-23 → 2024-11-08 (+46d) | 2024-10-04 → 2024-11-20 (+47d) | 10.5d → 9.33d | 77.85d → 42.5d | 1.04.16 FS+0.5d → 1.04.16 FS+1d |  |
| 1.04.17 | RELLENO SELECCIONADO PARA ZANJA con material propio | 2024-10-05 → 2024-11-21 (+47d) | 2024-10-15 → 2024-11-29 (+45d) | 7.5d → 6.67d | 77.85d → 42.5d | 1.04.24 FS+0.5d → 1.04.24 FS+1d |  |
| 1.04.21 | ENCOFRADO Y DESENCOFRADO RECTO | 2024-10-21 → 2024-12-02 (+42d) | 2024-10-25 → 2024-12-06 (+42d) | 4.5d → 3.67d | 77.85d → 42.5d | 1.04.23 FS+0.5d → 1.04.17 FS+2d |  |
| 1.04.23 | ACERO DE REFUERZO fy=4200 kg/cm2 | 2024-10-16 → 2024-12-04 (+49d) | 2024-10-19 → 2024-12-07 (+49d) | 3.5d → 3.17d | 77.85d → 42.5d | 1.04.17 FS+0.5d → 1.04.21 SS+2d |  |
| 1.04.22 | ENCOFRADO Y DESENCOFRADO CURVO | 2024-10-26 → 2024-12-06 (+41d) | 2024-11-06 → 2024-12-16 (+40d) | 8.5d → 7.33d | 77.85d → 42.5d | 1.04.21 FS+0.5d → 1.04.23 SS+2d |  |
| 1.04.15 | RELLENO ESTRUCTURAL PARA OBRAS DE ARTE, CON MATERIAL PROPIO | 2024-11-08 → 2024-12-17 (+39d) | 2024-11-14 → 2024-12-23 (+39d) |  | 77.85d → 42.5d | 1.04.20 FS+0.5d → 1.04.20 FS-1d |  |
| 1.04.20 | CONCRETO f'c=280 kg/cm2 (buzones) | 2024-11-07 → 2024-12-17 (+40d) | 2024-11-07 → 2024-12-17 (+40d) |  | 77.85d → 42.5d | 1.04.22 FS+0.5d → 1.04.22 FS+1d |  |
| 4 | **CANALES** | 2024-10-12 → 2024-11-18 (+37d) | 2024-11-20 → 2024-12-17 (+27d) |  |  |  |  |
| 1.04.25 | CONCRETO f'c=100 kg/cm2 | 2024-10-12 → 2024-11-18 (+37d) | 2024-10-12 → 2024-11-18 (+37d) | 0.5d → 1d | 72.99d → 47.33d |  |  |
| 1.04.28 | ACERO DE REFUERZO fy=4200 kg/cm2 | 2024-10-14 → 2024-11-19 (+36d) | 2024-11-02 → 2024-12-07 (+35d) | 16.5d → 15.5d | 72.99d → 47.33d |  |  |
| 1.04.27 | ENCOFRADO Y DESENCOFRADO RECTO | 2024-11-04 → 2024-11-30 (+26d) | 2024-11-19 → 2024-12-16 (+27d) | 13.5d → 12.33d | 72.99d → 47.33d | 1.04.28 FS+0.5d → 1.04.28 FS-6d |  |
| 1.04.26 | CONCRETO f'c=280 kg/cm2 | 2024-11-20 → 2024-12-17 (+27d) | 2024-11-20 → 2024-12-17 (+27d) | 0.53d → 0.5d | 72.99d → 47.33d | 1.04.27 FS+0.53d → 1.04.27 FS+0.5d |  |
| 1.04.29 | JUNTA WATER STOP SIN BULBO 150 mm | 2024-11-20 → 2024-12-17 (+27d) | 2024-11-20 → 2024-12-17 (+27d) | 0.53d → 0.5d | 72.99d → 47.33d |  |  |
| 5 | **OBRAS DE DESCARGA** | 2024-10-12 → 2024-11-13 (+32d) | 2024-10-29 → 2024-11-29 (+31d) |  |  |  |  |
| 1.04.30 | CONCRETO f'c=100 kg/cm2 | 2024-10-12 → 2024-11-13 (+32d) | 2024-10-12 → 2024-11-14 (+33d) |  | 90.65d → 61.17d | 1.08.04 FS+0.5d → 1.08.06 FS+0.5d |  |
| 1.04.33 | ACERO DE REFUERZO fy=4200 kg/cm2 | 2024-10-14 → 2024-11-14 (+31d) | 2024-10-16 → 2024-11-16 (+31d) | 2.5d → 2.33d | 90.65d → 61.17d | 1.04.30 FS+0.5d → 1.04.30 |  |
| 1.04.32 | ENCOFRADO Y DESENCOFRADO RECTO | 2024-10-17 → 2024-11-18 (+32d) | 2024-10-28 → 2024-11-28 (+31d) | 9.5d → 8.67d | 90.65d → 61.17d |  |  |
| 1.04.31 | CONCRETO f'c=280 kg/cm2 | 2024-10-29 → 2024-11-29 (+31d) | 2024-10-29 → 2024-11-29 (+31d) |  | 90.65d → 61.17d | 1.04.32 FS+0.5d → 1.04.32 FS+1d |  |
| 1.04.34 | JUNTA WATER STOP SIN BULBO 150 mm | 2024-10-29 → 2024-11-29 (+31d) | 2024-10-29 → 2024-11-29 (+31d) |  | 90.65d → 61.17d | 1.04.31 FS-0.1d → 1.04.31 SS |  |
| 6 | **RETORNOS** | 2024-10-15 → 2024-11-20 (+36d) | 2024-12-19 → 2025-01-23 (+35d) |  |  |  |  |
| 1 | **RETORNOS TIPO A2-OA-RE-I-11-25** | 2024-10-17 → 2024-11-20 (+34d) | 2024-11-15 → 2024-12-10 (+25d) |  |  |  |  |
| 1 | **OBRAS DE CONCRETO** | 2024-10-17 → 2024-11-20 (+34d) | 2024-11-12 → 2024-12-04 (+22d) |  |  |  |  |
| 1.04.35 | CONCRETO f'c=100 kg/cm2 | 2024-10-17 → 2024-11-20 (+34d) | 2024-10-17 → 2024-11-20 (+34d) |  | 76.78d → 53.5d | 1.08.08 FS+0.5d → 1.08.08 FS+1d |  |
| 1.04.38 | ACERO DE REFUERZO fy=4200 kg/cm2 | 2024-10-18 → 2024-11-21 (+34d) | 2024-10-29 → 2024-12-02 (+34d) | 9.5d → 8.67d | 76.78d → 53.5d |  |  |
| 1.04.37 | ENCOFRADO Y DESENCOFRADO RECTO | 2024-10-30 → 2024-11-23 (+24d) | 2024-11-09 → 2024-12-03 (+24d) | 8.5d → 7.67d | 76.78d → 53.5d | 1.04.38 FS+0.5d → 1.04.38 FS-7d |  |
| 1.04.39 | JUNTA WATER STOP SIN BULBO 150 mm | 2024-11-11 → 2024-12-02 (+21d) | 2024-11-12 → 2024-12-03 (+21d) | 1.59d → 1.5d | 79.69d → 58.5d | 1.04.36 SS → 1.04.37 FS-1d |  |
| 1.04.36 | CONCRETO f'c=280 kg/cm2 | 2024-11-11 → 2024-12-04 (+23d) | 2024-11-11 → 2024-12-04 (+23d) |  | 76.78d → 53.5d | 1.04.37 FS+0.5d → 1.04.37 FS+1d |  |
| 2 | **ESTRUCTURAS METALICAS** | 2024-11-12 → 2024-12-05 (+23d) | 2024-11-15 → 2024-12-10 (+25d) |  |  |  |  |
| 1.04.40 | COMPUERTA METALICA PLANA DESLIZANTE DE 1.0x1.0 m | 2024-11-12 → 2024-12-05 (+23d) | 2024-11-13 → 2024-12-06 (+23d) | 1.5d → 1d | 76.78d → 53.5d | 1.04.36 FS+0.5d → 1.04.36 FS+1d |  |
| 1.04.41 | BARANDA DE FIERRO GALVANIZADO 1 1/2" | 2024-11-14 → 2024-12-09 (+25d) | 2024-11-15 → 2024-12-10 (+25d) | 1.5d → 1d | 76.78d → 53.5d | 1.04.40 FS+0.5d → 1.04.40 FS+1d |  |
| 2 | **RETORNOS Q=100 A 1000 l/s** | 2024-10-15 → 2024-11-29 (+45d) | 2024-12-19 → 2025-01-23 (+35d) |  |  |  |  |
| 1 | **OBRAS DE CONCRETO** | 2024-10-30 → 2024-12-14 (+45d) | 2024-11-30 → 2025-01-06 (+37d) |  |  |  |  |
| 1.04.42 | CONCRETO f'c=100 kg/cm2 | 2024-10-30 → 2024-12-14 (+45d) | 2024-10-30 → 2024-12-16 (+47d) | 0.53d → 0.5d | 47.83d → 18.71d | 1.08.11 FS+0.47d, 1.04.46 FF-1.5d → 1.08.11 FS+0.5d |  |
| 1.04.45 | ACERO DE REFUERZO fy=4200 kg/cm2 | 2024-10-31 → 2024-12-16 (+46d) | 2024-11-18 → 2025-01-03 (+46d) | 14.76d → 13d | 47.83d → 18.71d | 1.04.42 FS+0.42d → 1.04.42 FS+0.4d |  |
| 1.04.44 | ENCOFRADO Y DESENCOFRADO RECTO | 2024-11-19 → 2024-12-23 (+34d) | 2024-11-29 → 2025-01-04 (+36d) | 9.5d → 8d | 47.83d → 18.71d | 1.04.45 FS+0.5d → 1.04.45 FS-7d |  |

| ID | Task | Start | Finish | Duration | Total float | Predecessors |
| --- | --- | --- | --- | --- | --- | --- |
| 1.04.43 | CONCRETO f'c=280 kg/cm2 | 2024-11-30 → 2025-01-06 (+37d) | 2024-11-30 → 2025-01-06 (+37d) |  | 47.83d → 18.71d | 1.04.44 FS+0.5d → 1.04.44 FS+1d |
| 2 | **TUBERÍAS** | 2024-10-15 → 2024-11-29 (+45d) | 2024-10-28 → 2024-12-12 (+45d) |  |  |  |
| 1.04.46 | SUMINISTRO E INSTALACIÓN DE TUBERÍA HDPE DN600 mm | 2024-10-15 → 2024-11-29 (+45d) | 2024-10-28 → 2024-12-12 (+45d) | 11.5d → 10.33d | 51.33d → 51.5d | 1.08.10 FS+0.5d → 1.08.10 FS+1d |
| 3 | **COMPUERTAS Y VÁLVULAS** | 2024-12-02 → 2025-01-06 (+35d) | 2024-12-19 → 2025-01-23 (+35d) |  |  |  |
| 1.04.47 | COMPUERTA TIPO CLAPETA DN600 mm | 2024-12-02 → 2025-01-06 (+35d) | 2024-12-19 → 2025-01-23 (+35d) | 15.5d → 14.33d | 47.83d → 18.71d | 1.04.43 FS+0.5d → 1.04.43 |
| 5 | **ARQUITECTURA Y PAISAJISMO** | 2024-10-23 → 2024-12-05 (+43d) | 2024-11-05 → 2024-12-19 (+44d) |  |  |  |
| 1 | **INTERVENCION PAISAJISMO - CRUCE AVENIDA PERU** | 2024-10-23 → 2024-12-05 (+43d) | 2024-11-05 → 2024-12-19 (+44d) |  |  |  |
| 1 | **OBRAS PRELIMINARES** | 2024-10-23 → 2024-12-05 (+43d) | 2024-11-05 → 2024-12-19 (+44d) |  |  |  |
| 1.05.01 | MOVILIZACIÓN Y DEMOVILIZACIÓN DE EQUIPOS Y HERRAMIENTAS (ARQUITECTURA Y PAISAJISMO) | 2024-10-23 → 2024-12-05 (+43d) | 2024-10-25 → 2024-12-07 (+43d) | 2.5d → 2.33d | 87.94d → 54.83d | 1.05.03 FS-4.5d → 1.05.03 FS-6d |
| 1.05.02 | TRAZO Y REPLANTEO PRELIMINAR | 2024-10-28 → 2024-12-12 (+45d) | 2024-11-05 → 2024-12-19 (+44d) | 6.5d → 6.67d | 85.97d → 45d | 1.05.03 SS-0.1d → 1.05.03 SS |
| 2 | **MOBILIARIOS, BARANDAS Y ESCALERAS** | 2024-10-28 → 2024-12-12 (+45d) | 2024-11-05 → 2024-12-19 (+44d) |  |  |  |
| 1.05.03 | ESCALERA DE CONCRETO SOBRE ENROCADO, CIMENTACION Y ANCLAJE | 2024-10-28 → 2024-12-12 (+45d) | 2024-10-28 → 2024-12-12 (+45d) | 0.53d → 0.5d | 85.69d → 45d | 1.09.22 FS+0.53d → 1.09.22 FS+0.5d |
| 1.05.04 | BARANDA DE MADERA EUCALIPTO CON SOGA, INCLUYE CIMENTACIÓN | 2024-10-29 → 2024-12-13 (+45d) | 2024-10-29 → 2024-12-13 (+45d) |  | 85.69d → 45.17d | 1.05.03 FS+0.5d → 1.05.03 FS+1d |
| 1.05.05 | TACHOS DE BASURA, INCLUYE CIMENTACIÓN | 2024-10-30 → 2024-12-14 (+45d) | 2024-10-30 → 2024-12-16 (+47d) | 0.53d → 0.5d | 85.69d → 45.17d | 1.05.04 FS+0.53d → 1.05.04 FS+0.5d |
| 1.05.06 | BANCAS DE CONCRETO, INCLUYE CIMENTACIÓN | 2024-10-31 → 2024-12-16 (+46d) | 2024-10-31 → 2024-12-17 (+47d) | 0.53d → 0.5d | 85.69d → 45.17d | 1.05.05 FS+0.53d → 1.05.05 FS+0.5d |
| 1.05.07 | POSTES DE ILUMINACIÓN, INCLUYE LUMINARIA Y CIMENTACIÓN | 2024-11-02 → 2024-12-17 (+45d) | 2024-11-04 → 2024-12-18 (+44d) | 1.5d → 0.5d | 85.69d → 45.17d | 1.05.06 FS+0.53d → 1.05.06 FS+0.5d |
| 1.05.08 | SEÑALETICA INFORMATIVA | 2024-11-05 → 2024-12-19 (+44d) | 2024-11-05 → 2024-12-19 (+44d) |  | 85.69d → 45.17d | 1.05.07 FS+0.5d → 1.05.07 FS+1d |
| 1 | **MEJORAMIENTO DE VÍAS EXISTENTES** |  | 2024-06-04 → 2025-02-07 (+248d) |  |  |  |
| 1.06.01 | ROCE Y LIMPIEZA DE MALEZA |  |  | 5.5d → 4.67d | 212.67d → 343.64d | A1040 SS-0.4d → 1.07.02 SS-0.2d |
| 1.06.02 | REHABILITACIÓN DE VÍAS EXISTENTES | 2023-12-05 → 2023-11-28 (-7d) | 2024-06-04 → 2025-02-07 (+248d) | 149.5d → 340.56d | 212.67d → 7.11d | 1.06.01 FS+0.5d → 1.01.03 SS |
| 1.06.03 | CONFORMACIÓN DE TERRAPLENES EN CAMINO | 2023-12-05 → 2023-12-04 (-1d) | 2023-12-07 → 2023-12-04 (-3d) | 2.53d → 0.5d | 359.64d → 343.17d | 1.06.01 FS+0.5d → 1.06.02 SS+4d |
| 1.07.01 | DESBROCE Y LIMPIEZA EN ZONA NO BOSCOSA |  |  | 16.5d → 15d | 351.67d → 1.89d | A1040 SS-0.4d → 01.02.01 SS+3d |
| 1.07.02 | DESCOLMATACIÓN DE DESCOLMATACIÓN DE CAUCE NATURAL DEL RÍO LACRAMARCA |  |  | 56.5d → 53d | 286.57d → 1.89d | A1040 SS-0.4d → 1.07.01 SS |
| 1.07.03 | CONFORMACIÓN DE DESVIO EN CAUCE DE RÍO |  |  | 34.5d → 32.33d | 286.57d → 271.44d |  |
| 1.07.04 | RELLENO NO ESTRUCTURAL CON MATERIAL PROPIO (canal) |  |  | 46.5d → 43.33d | 286.57d → 271.44d | 1.07.03 FS-5.4d → 1.07.03 FS-5d |
| 3 | **DIQUES DE TIERRA COMPACTADA CON ENROCADO** |  | 2025-01-21 → 2025-01-11 (-10d) |  |  |  |
| 1 | **EXCAVACIÓN EN TERRENO NATURAL CON EQUIPO** |  | 2024-05-07 → 2024-04-06 (-31d) |  |  |  |
| 1.07.05 | EXCAVACIÓN EN TERRENO NATURAL CON EQUIPO (A2-D-02) | 2024-03-04 → 2023-11-28 (-97d) | 2024-03-08 → 2023-12-14 (-85d) | 4.5d → 12d | 206.05d → 0d | 1.07.15 FS+0.5d → 01.02.01 SS+3d |
| 1.07.07 | EXCAVACIÓN EN TERRENO NATURAL CON EQUIPO (A2-I-03) | 2023-12-13 → 2023-11-28 (-15d) | 2023-12-22 → 2023-12-26 (+4d) | 8.5d → 20.33d | 8.81d → 0d | 1.07.17 FS+0.5d → 1.07.05 SS |
| 1.07.06 | EXCAVACIÓN EN TERRENO NATURAL CON EQUIPO (A2-D-01) | 2023-12-27 → 2023-12-15 (-12d) | 2024-03-01 → 2024-04-06 (+36d) | 55.5d → 87.11d | 8.81d → 20.67d | 1.07.14 FS+0.5d → 1.07.05 FS+1d |
| 1.07.08 | EXCAVACIÓN EN TERRENO NATURAL CON EQUIPO (A2-I-02) | 2023-12-02 → 2023-12-27 (+25d) | 2024-02-05 → 2024-03-04 (+28d) | 51.5d → 53.67d |  | 1.07.16 FS+0.5d → 1.07.07 FS+1d |
| 1.07.09 | EXCAVACIÓN EN TERRENO NATURAL CON EQUIPO (A2-I-01-B) | 2023-11-28 → 2024-03-05 (+98d) | 2023-11-29 → 2024-03-08 (+100d) | 1.5d → 2.67d | 0d → 36.51d | 01.02.01 SS+3d → 1.07.08 FS+1d |
| 1.07.10 | EXCAVACIÓN EN TERRENO NATURAL CON EQUIPO (A2-I-01) | 2023-11-28 → 2024-03-09 (+102d) | 2023-12-07 → 2024-03-21 (+105d) | 8.5d → 9.11d | 8.81d → 208.17d | 01.02.01 SS+3d → 1.07.09 FS+1d |
| 1.07.11 | EXCAVACIÓN EN TERRENO NATURAL CON EQUIPO (RAMPAS) | 2024-04-30 → 2024-03-22 (-39d) | 2024-04-30 → 2024-03-23 (-38d) | 0.5d → 0.83d | 236.05d → 248.83d | EXCAVACIÓN DE UÑA CON EQUIPO LIBERACIÓN PREDIAL LI FS+0.5d → 1.07.10 FS+1d |
| 2 | **EXCAVACIÓN DE UÑA CON EQUIPO** | 2023-11-30 → 2023-12-12 (+12d) | 2024-05-20 → 2024-04-06 (-44d) |  |  |  |
| 1.07.12 | EXCAVACIÓN DE UÑA CON EQUIPO (A2-D-02) | 2024-03-09 → 2023-12-12 (-88d) | 2024-03-09 → 2023-12-14 (-86d) | 0.5d → 2d | 206.05d → 336.11d | 1.07.05 FS+0.5d → 1.07.05 FS-2d |
| 1.07.14 | EXCAVACIÓN DE UÑA CON EQUIPO (A2-I-03) | 2023-12-23 → 2023-12-15 (-8d) |  | 1.5d → 7.67d | 8.81d → 328.11d | 1.07.07 FS+0.5d → 1.07.07 FS-8d |
| 1.07.15 | EXCAVACIÓN DE UÑA CON EQUIPO (A2-I-02) | 2024-02-06 → 2024-02-05 (-1d) | 2024-03-02 → 2024-03-04 (+2d) | 22.5d → 23d | 0d → 273.11d | 1.07.08 FS+0.5d → 1.07.08 FS-23d |
| 1.07.13 | EXCAVACIÓN DE UÑA CON EQUIPO (A2-D-01) | 2024-03-02 → 2024-03-04 (+2d) | 2024-03-21 → 2024-04-06 (+16d) | 16.5d → 25.56d | 8.81d → 247.44d | 1.07.06 FS+0.5d → 1.07.06 FS-25d |
| 1.07.16 | EXCAVACIÓN DE UÑA CON EQUIPO (A2-I-01-B) | 2023-11-30 → 2024-03-05 (+96d) | 2023-12-01 → 2024-03-08 (+98d) | 1.5d → 3.33d | 0d → 269.11d | 1.07.09 FS+0.5d → 1.07.09 FS-3d |
| 1.07.17 | EXCAVACIÓN DE UÑA CON EQUIPO (A2-I-01) | 2023-12-11 → 2024-03-15 (+95d) | 2023-12-12 → 2024-03-21 (+100d) | 1.5d → 4d | 8.81d → 259.33d | 1.07.10 FS+0.5d → 1.07.10 FS-4d |
| 3 | **PERFILADO Y COMPACTACIÓN EN ZONA DE CORTE EN CORONA** | 2023-12-21 → 2024-02-03 (+44d) | 2025-01-21 → 2025-01-11 (-10d) |  |  |  |
| 1.07.18 | PERFILADO Y COMPACTACIÓN EN ZONA DE CORTE EN CORONA (A2-D-02) | 2024-04-04 → 2024-02-03 (-61d) | 2024-04-04 → 2024-02-06 (-58d) | 0.5d → 2d | 264.05d → 294.66d | 1.07.50 FS+0.5d → 1.07.50 FS+1d |
| 1.07.20 | PERFILADO Y COMPACTACIÓN EN ZONA DE CORTE EN CORONA (A2-I-03) | 2024-01-23 → 2024-02-12 (+20d) | 2024-01-23 → 2024-02-14 (+22d) | 0.5d → 1.33d | 324.05d → 288.64d | 1.07.52 FS+0.5d → 1.07.52 FS+1.5d |
| 1.07.22 | PERFILADO Y COMPACTACIÓN EN ZONA DE CORTE EN CORONA (A2-I-01-B) | 2023-12-21 → 2024-03-23 (+93d) | 2023-12-21 → 2024-03-23 (+93d) | 0.53d → 0.5d | 350.02d → 256.94d |  |
| 1.07.19 | PERFILADO Y COMPACTACIÓN EN ZONA DE CORTE EN CORONA (A2-D-01) | 2025-01-16 → 2024-10-05 (-103d) | 2025-01-20 → 2024-10-12 (-100d) | 3.5d → 5d | 23.05d → 99d |  |
| 1.07.21 | PERFILADO Y COMPACTACIÓN EN ZONA DE CORTE EN CORONA (A2-I-02) | 2025-01-17 → 2025-01-08 (-9d) | 2025-01-21 → 2025-01-11 (-10d) | 3.5d → 3d |  | 1.07.53 FS+0.5d → 1.07.53 FS+1d |
| 10 | **PERFILADO EN ZONA DE CORTE EN TALUD DE DIQUE** | 2023-12-05 → 2023-12-16 (+11d) | 2024-08-26 → 2024-05-22 (-96d) |  |  |  |
| 1.07.24 | PERFILADO EN ZONA DE CORTE DE TALUD DE DIQUE (A2-D-02) | 2024-03-13 → 2023-12-16 (-88d) | 2024-03-16 → 2023-12-27 (-80d) | 3.5d → 7.67d | 264.05d → 326.94d | 1.07.40 FS+0.5d → 1.07.30 FS+0.5d |
| 1.07.26 | PERFILADO EN ZONA DE CORTE TALUD DE DIQUE (A2-I-03) | 2023-12-30 → 2023-12-28 (-2d) | 2024-01-04 → 2024-01-06 (+2d) | 3.5d → 6.33d | 324.05d → 319.44d | 1.07.42 FS+0.5d → 1.07.31 FS+1d |
| 1.07.28 | PERFILADO EN ZONA DE CORTE TALUD DE DIQUE (A2-I-01-B) | 2023-12-05 → 2024-03-11 (+97d) | 2023-12-06 → 2024-03-12 (+97d) | 1.5d → 0.67d | 45.55d → 266.68d | 1.07.44 FS+0.5d → 1.07.33 FS+1d |
| 1.07.27 | PERFILADO EN ZONA DE CORTE TALUD DE DIQUE (A2-I-02) | 2024-06-17 → 2024-03-12 (-97d) | 2024-07-03 → 2024-04-19 (-75d) | 13.5d → 29.56d | 0d → 237.56d | 1.07.48 FS+0.5d → 1.07.32 FS+1d |
| 1.07.29 | PERFILADO EN ZONA DE CORTE DE TALUD DE DIQUE (A2-I-01) | 2024-01-17 → 2024-03-22 (+65d) | 2024-01-19 → 2024-03-25 (+66d) | 2.5d → 1.5d | 314.05d → 208.17d | 1.07.49 FS+0.5d → 1.07.10 FS+1.5d |
| 1.07.25 | PERFILADO EN ZONA DE CORTE EN TALUD DE DIQUE (A2-D-01) | 2024-08-13 → 2024-04-08 (-127d) | 2024-08-26 → 2024-05-22 (-96d) | 11.5d → 35d | 23.05d → 100.17d | 1.07.47 FS+0.5d → 1.07.06 FS+1d |
| 11 | **PREPARACIÓN DE FUNDACIÓN DE CUERPO DE DIQUE** | 2023-12-02 → 2023-12-15 (+13d) | 2024-05-21 → 2024-03-11 (-71d) |  |  |  |
| 1.07.30 | PREPARACIÓN DE FUNDACIÓN DE CUERPO DE DIQUE (A2-D-02) | 2024-03-11 → 2023-12-15 (-87d) | 2024-03-11 → 2023-12-15 (-87d) |  | 264.05d → 326.94d | 1.07.12 FS+0.5d → 1.07.05 FS+0.5d |
| 1.07.31 | PREPARACIÓN DE FUNDACIÓN DE CUERPO DE DIQUE (A2-I-03) |  |  |  | 324.05d → 319.44d | 1.07.14 FS+0.5d → 1.07.07 FS+0.5d |
| 1.07.32 | PREPARACIÓN DE FUNDACIÓN DE CUERPO DE DIQUE (A2-I-02) | 2024-03-04 → 2024-03-05 (+1d) | 2024-03-08 → 2024-03-11 (+3d) | 4.24d → 4d |  | 1.07.15 FS+0.5d → 1.07.08 FS+1d |
| 1.07.33 | PREPARACIÓN DE FUNDACIÓN DE CUERPO DE DIQUE (A2-I-01-B) | 2023-12-02 → 2024-03-09 (+98d) | 2023-12-02 → 2024-03-09 (+98d) |  | 45.55d → 266.68d | 1.07.16 FS+0.5d → 1.07.09 FS+0.6d |
| 4 | **PEDRAPLÉN e=60 cm** | 2023-12-13 → 2024-03-12 (+90d) | 2024-06-27 → 2024-09-24 (+89d) |  |  |  |
| 1.07.36 | PEDRAPLEN e=60 cm (A2-I-01) | 2023-12-13 → 2024-03-26 (+104d) | 2023-12-29 → 2024-04-17 (+110d) | 13.5d → 16.67d | 25.85d → 208.17d | 1.07.17 FS+0.5d → 1.07.29 FS+1d |
| 1.07.34 | PEDRAPLEN e=60 cm (A2-D-01) | 2024-03-22 → 2024-05-23 (+62d) | 2024-06-06 → 2024-09-24 (+110d) | 62.5d → 98d | 23.05d → 100.17d | 1.07.13 FS+0.5d → 1.07.25 FS+1d |
| 5 | **PEDRAPLÉN e=30 cm** | 2023-12-30 → 2024-04-04 (+96d) | 2024-07-04 → 2024-10-11 (+99d) |  |  |  |
| 1.07.38 | PEDRAPLEN e=30 cm (A2-I-02) | 2024-03-30 → 2024-04-04 (+5d) | 2024-04-08 → 2024-04-13 (+5d) | 7.5d → 8.33d |  | PEDRAPLÉN e=60 cm (A2-I-02) FS+0.5d → 1.07.35 FS+1d |
| 1.07.39 | PEDRAPLEN e=30 cm (A2-I-01) | 2023-12-30 → 2024-04-18 (+110d) | 2024-01-02 → 2024-04-23 (+112d) | 1.5d → 3.67d | 314.05d → 208.17d |  |
| 1.07.37 | PEDRAPLEN e=30 cm (A2-D-01) | 2024-06-07 → 2024-09-25 (+110d) | 2024-06-17 → 2024-10-11 (+116d) | 8.5d → 12.33d | 23.05d → 100.17d |  |
| 6 | **CONFORMACIÓN DE CUERPO DE DIQUE CON MATERIAL PROPIO** | 2023-12-04 → 2023-12-15 (+11d) | 2024-08-07 → 2024-06-03 (-65d) |  |  |  |
| 1.07.40 | CONFORMACIÓN DE CUERPO DE DIQUE CON MATERIAL PROPIO (A2-D-02) | 2024-03-12 → 2023-12-15 (-88d) | 2024-03-12 → 2023-12-16 (-87d) | 0.5d → 0.56d | 264.05d → 48.33d | 1.07.30 FS+0.5d → 1.07.05 FS+1d |
| 1.07.41 | CONFORMACIÓN DE CUERPO DE DIQUE CON MATERIAL PROPIO (A2-D-01) | 2024-06-18 → 2023-12-18 (-183d) | 2024-08-07 → 2024-02-10 (-179d) | 41.5d → 43.17d | 23.05d → 99d | 1.07.37 FS+0.5d → 1.07.40 FS+0.5d |
| 1.07.42 | CONFORMACIÓN DE CUERPO DE DIQUE CON MATERIAL PROPIO (A2-I-03) | 2023-12-28 → 2023-12-27 (-1d) | 2023-12-29 → 2023-12-28 (-1d) | 1.5d → 1.3d | 324.05d → 288.64d | 1.07.31 FS+0.5d → 1.07.07 FS+0.5d |

| ID | Task | Start | Finish | Duration | Total float | Predecessors |
| --- | --- | --- | --- | --- | --- | --- |
| 1.07.44 | CONFORMACIÓN DE CUERPO DE DIQUE CON MATERIAL PROPIO (A2-I-01-B) | 2023-12-04 → 2024-03-09 (+96d) | 2023-12-04 → 2024-03-09 (+96d) | 0.5d → 0.62d | 45.55d → 36.51d | 1.07.33 FS+0.5d, A1050 SF → 1.07.09 FS+0.6d |
| 1.07.46 | CONFORMACIÓN DE CUERPO DE RAMPA CON MATERIAL PROPIO | 2024-05-02 → 2024-03-25 (-38d) | 2024-05-04 → 2024-04-02 (-32d) | 2.5d → 4.67d | 236.05d → 248.83d | 1.07.11 FS+0.5d → 1.07.11 FS+1d |
| 1.07.43 | CONFORMACIÓN DE CUERPO DE DIQUE CON MATERIAL PROPIO (A2-I-02) | 2024-04-09 → 2024-04-15 (+6d) | 2024-06-13 → 2024-06-03 (-10d) | 55.5d → 39d |  |  |
| 1.07.45 | CONFORMACIÓN DE CUERPO DE DIQUE CON MATERIAL PROPIO (A2-I-01) | 2024-01-03 → 2024-04-24 (+112d) | 2024-01-13 → 2024-05-04 (+112d) | 9.5d → 7.5d | 314.05d → 208.17d | 1.07.39 FS+0.5d → 1.07.39 FS+1d |
| 7 | **CONFORMACIÓN DE RELLENO NO ESTRUCTURAL CON MATERIAL PROPIO** | 2024-01-15 → 2024-01-27 (+12d) | 2024-08-12 → 2024-06-03 (-70d) |  |  |  |
| 1.07.47 | CONFORMACIÓN DE RELLENO NO ESTRUCTURAL CON MATERIAL PROPIO (A2-D-01) | 2024-08-08 → 2024-01-27 (-194d) | 2024-08-12 → 2024-02-10 (-184d) | 3.5d → 11.67d | 23.05d → 291.22d | 1.07.41 FS+0.5d → 1.07.41 FS-12d |
| 1.07.49 | CONFORMACIÓN DE RELLENO NO ESTRUCTURAL CON MATERIAL PROPIO (A2-I-01) | 2024-01-15 → 2024-05-02 (+108d) | 2024-01-16 → 2024-05-06 (+111d) | 1.5d → 2.67d | 314.05d → 224.83d | 1.07.45 FS+0.5d → 1.07.45 FS-1.5d |
| 1.07.48 | CONFORMACIÓN DE RELLENO NO ESTRUCTURAL CON MATERIAL PROPIO (A2-I-02) | 2024-06-14 → 2024-05-30 (-15d) | 2024-06-15 → 2024-06-03 (-12d) | 1.5d → 3d | 0d → 202.28d | 1.07.43 FS+0.5d → 1.07.43 FS-3d |
| 8 | **CONFORMACIÓN DE MATERIAL GRANULAR EN CORONA DE DIQUE** | 2023-12-19 → 2024-01-26 (+38d) | 2025-01-16 → 2025-01-07 (-9d) |  |  |  |
| 1.07.50 | CONFORMACIÓN DE MATERIAL GRANULAR EN CORONA DE DIQUE (A2-D-02) | 2024-04-01 → 2024-01-26 (-66d) | 2024-04-03 → 2024-02-02 (-61d) | 2.5d → 6d | 264.05d → 294.66d | 1.07.63 FS+0.5d → 1.07.63 FS+1d |
| 1.07.52 | CONFORMACIÓN DE MATERIAL GRANULAR EN CORONA DE DIQUE (A2-I-03) | 2024-01-19 → 2024-02-03 (+15d) | 2024-01-22 → 2024-02-10 (+19d) | 2.5d → 5.33d | 324.05d → 288.64d |  |
| 1.07.54 | CONFORMACIÓN DE MATERIAL GRANULAR EN CORONA DE DIQUE (A2-I-01-B) | 2023-12-19 → 2024-03-21 (+93d) | 2023-12-20 → 2024-03-22 (+93d) | 1.5d → 1.33d | 350.02d → 256.94d | 1.07.67 FS+0.5d → 1.07.67 FS+1d |
| 1.07.56 | CONFORMACIÓN DE CORONA DE RAMPA | 2024-05-06 → 2024-04-03 (-33d) | 2024-05-08 → 2024-04-05 (-33d) | 2.5d → 2d | 236.05d → 248.83d | 1.07.46 FS+0.5d → 1.07.46 FS+1d |
| 1.07.55 | CONFORMACIÓN DE MATERIAL GRANULAR EN CORONA DE DIQUE (A2-I-01) | 2024-02-01 → 2024-05-22 (+111d) | 2024-02-03 → 2024-05-25 (+112d) | 2.5d → 3d | 314.05d → 208.17d | 1.07.68 FS+0.5d → 1.07.68 FS+1d |
| 1.07.51 | CONFORMACIÓN DE MATERIAL GRANULAR EN CORONA DE DIQUE (A2-D-01) | 2024-12-24 → 2024-09-24 (-91d) | 2025-01-15 → 2024-10-04 (-103d) | 17.5d → 8.67d | 23.05d → 99d | 1.07.64 FS+0.5d → 1.07.64 FS+1d |
| 1.07.53 | CONFORMACIÓN DE MATERIAL GRANULAR EN CORONA DE DIQUE (A2-I-02) | 2024-12-10 → 2024-12-23 (+13d) | 2025-01-16 → 2025-01-07 (-9d) | 30.5d → 10.33d |  | 1.07.66 FS+0.5d → 1.07.66 FS+1d |
| 9 | **GEOTEXTIL NO TEJIDO 400 G/M2, INC. COLOCACIÓN** | 2023-12-07 → 2023-12-18 (+11d) | 2024-09-12 → 2024-07-22 (-52d) |  |  |  |
| 1.07.57 | GEOTEXTIL NO TEJIDO 400 G/M2, INC. COLOCACIÓN (A2-D-02) | 2024-03-18 → 2023-12-18 (-91d) | 2024-03-19 → 2023-12-29 (-81d) | 1.5d → 8.67d | 264.05d → 48.33d | 1.07.24 FS+0.5d → 1.07.40 FS+0.5d |
| 1.07.59 | GEOTEXTIL NO TEJIDO 400 G/M2, INC. COLOCACIÓN (A2-I-03) | 2024-01-05 → 2023-12-29 (-7d) | 2024-01-06 → 2024-01-09 (+3d) | 1.5d → 7.67d | 324.05d → 288.64d | 1.07.26 FS+0.5d → 1.07.42 FS+1d |
| 1.07.58 | GEOTEXTIL NO TEJIDO 400 G/M2, INC. COLOCACIÓN (A2-D-01) | 2024-08-27 → 2024-02-12 (-197d) | 2024-09-12 → 2024-04-06 (-159d) | 13.5d → 42.56d | 23.05d → 99d | 1.07.25 FS+0.5d → 1.07.41 FS+0.5d |
| 1.07.61 | GEOTEXTIL NO TEJIDO 400 G/M2, INC. COLOCACIÓN (A2-I-01-B) | 2023-12-07 → 2024-03-11 (+95d) | 2023-12-11 → 2024-03-13 (+93d) | 1.5d → 2d | 45.55d → 256.94d | 1.07.28 FS+0.5d → 1.07.44 FS+0.5d |
| 1.07.62 | GEOTEXTIL NO TEJIDO 400 G/M2, INC. COLOCACIÓN (A2-I-01) | 2024-01-20 → 2024-05-06 (+107d) | 2024-01-22 → 2024-05-09 (+108d) | 1.5d → 3d | 314.05d → 208.17d | 1.07.29 FS+0.5d → 1.07.45 FS+0.5d |
| 1.07.60 | GEOTEXTIL NO TEJIDO 400 G/M2, INC. COLOCACIÓN (A2-I-02) | 2024-07-04 → 2024-06-04 (-30d) | 2024-07-25 → 2024-07-22 (-3d) | 18.5d → 37.33d |  | 1.07.27 FS+0.5d → 1.07.43 FS+1d |
| 12 | **COLOCACION Y ACOMODO DE ROCA EN TALUD DE DIQUE** | 2023-12-16 → 2024-01-11 (+26d) | 2024-12-23 → 2024-12-21 (-2d) |  |  |  |
| 1.07.63 | COLOCACION Y ACOMODO DE ROCA EN TALUD DE DIQUE (A2-D-02) | 2024-03-23 → 2024-01-11 (-72d) | 2024-03-30 → 2024-01-25 (-65d) | 4.5d → 11d | 264.05d → 294.66d | COLOCACION Y ACOMODO DE ROCA EN UÑA DE DIQUE A2-D-02 FS+0.5d → 1.03.01 FS+1d |
| 1.07.65 | COLOCACION Y ACOMODO DE ROCA EN TALUD DE DIQUE (A2-I-03) | 2024-01-12 → 2024-01-19 (+7d) | 2024-01-18 → 2024-02-02 (+15d) | 5.5d → 12d | 324.05d → 288.64d | COLOCACION Y ACOMODO DE ROCA EN UÑA DE DIQUE A2-I-03 FS+0.5d → 1.03.03 FS+1d |
| 1.07.67 | COLOCACION Y ACOMODO DE ROCA EN TALUD DE DIQUE (A2-I-01-B) | 2023-12-16 → 2024-03-19 (+94d) | 2023-12-18 → 2024-03-20 (+93d) | 1.5d → 0.67d | 350.02d → 256.94d | COLOCACION Y ACOMODO DE ROCA EN UÑA DE DIQUE A2-I-01-B FS+0.5d → 1.03.05 FS+1d |
| 1.07.68 | COLOCACION Y ACOMODO DE ROCA EN TALUD DE DIQUE (A2-I-01) | 2024-01-29 → 2024-05-17 (+109d) | 2024-01-31 → 2024-05-21 (+111d) | 2.5d → 2.33d | 314.05d → 208.17d | COLOCACION Y ACOMODO DE ROCA EN UÑA DE DIQUE A2-I-01 FS+0.5d → 1.03.06 FS+1d |
| 1.07.64 | COLOCACION Y ACOMODO DE ROCA EN TALUD DE DIQUE (A2-D-01) | 2024-11-12 → 2024-07-13 (-122d) | 2024-12-23 → 2024-09-23 (-91d) | 35.5d → 56d | 23.05d → 99d | COLOCACION Y ACOMODO DE ROCA EN UÑA DE DIQUE A2-D-01 FS+0.5d → 1.03.02 FS+0.5d |
| 1.07.66 | COLOCACION Y ACOMODO DE ROCA EN TALUD DE DIQUE (A2-I-02) | 2024-10-12 → 2024-10-18 (+6d) | 2024-12-09 → 2024-12-21 (+12d) | 48.5d → 50.67d |  | COLOCACION Y ACOMODO DE ROCA EN UÑA DE DIQUE A2-I-02 FS+0.5d → 1.03.04 FS+1d |
| 4 | **OBRAS DE ARTE** | 2024-08-28 → 2024-10-14 (+47d) | 2024-10-29 → 2024-12-13 (+45d) |  |  |  |
| 1 | **TOMAS O CAPTACIONES** | 2024-08-28 → 2024-10-14 (+47d) | 2024-10-01 → 2024-11-06 (+36d) |  |  |  |
| 1 | **MOVIMIENTO DE TIERRAS** | 2024-08-28 → 2024-10-14 (+47d) | 2024-10-01 → 2024-11-06 (+36d) |  |  |  |
| 1.08.01 | EXCAVACION ESTRUCTURAL PARA OBRAS DE ARTE | 2024-08-28 → 2024-10-14 (+47d) | 2024-09-14 → 2024-10-30 (+46d) | 14.5d → 14.33d | 8.81d → 20.67d | EXCAVACIÓN DE UÑA CON EQUIPO LIBERACIÓN PREDIAL LD FS+83.5d → 1.07.06 FS+149d |
| 1.08.02 | RELLENO ESTRUCTURAL PARA OBRAS DE ARTE CON MATERIAL PROPIO | 2024-09-16 → 2024-10-21 (+35d) | 2024-10-01 → 2024-11-06 (+36d) | 13.5d → 12.22d | 8.81d → 24.07d | 1.08.01 FS+0.5d → 1.08.01 FS-8d |
| 2 | **CANALES** | 2024-09-16 → 2024-10-31 (+45d) | 2024-10-11 → 2024-11-16 (+36d) |  |  |  |
| 1 | **MOVIMIENTO DE TIERRAS** | 2024-09-16 → 2024-10-31 (+45d) | 2024-10-11 → 2024-11-16 (+36d) |  |  |  |
| 1.08.03 | EXCAVACION ESTRUCTURAL PARA OBRAS DE ARTE | 2024-09-16 → 2024-10-31 (+45d) | 2024-09-24 → 2024-11-09 (+46d) | 7.5d → 6.67d | 47.83d → 20.67d | 1.08.01 FS+0.53d → 1.08.01 FS+0.5d |
| 1.08.04 | RELLENO ESTRUCTURAL PARA OBRAS DE ARTE CON MATERIAL PROPIO | 2024-10-02 → 2024-11-08 (+37d) | 2024-10-11 → 2024-11-16 (+36d) | 7.5d → 8d | 72.99d → 61d | 1.08.02 FS+0.5d → 1.08.02 FS+2d |
| 3 | **OBRAS DE DESCARGA** | 2024-09-25 → 2024-11-11 (+47d) | 2024-09-26 → 2024-11-13 (+48d) |  |  |  |
| 1 | **MOVIMIENTO DE TIERRAS** | 2024-09-25 → 2024-11-11 (+47d) | 2024-09-26 → 2024-11-13 (+48d) |  |  |  |
| 1.08.05 | EXCAVACION ESTRUCTURAL PARA OBRAS DE ARTE | 2024-09-25 → 2024-11-11 (+47d) | 2024-09-26 → 2024-11-12 (+47d) | 1.5d → 1d | 47.83d → 20.67d |  |
| 4 | **RETORNOS TIPO A2-OA-RE-I-11-25** | 2024-09-27 → 2024-11-13 (+47d) | 2024-10-16 → 2024-11-19 (+34d) |  |  |  |
| 1 | **MOVIMIENTO DE TIERRAS** | 2024-09-27 → 2024-11-13 (+47d) | 2024-10-16 → 2024-11-19 (+34d) |  |  |  |
| 1.08.07 | EXCAVACION ESTRUCTURAL PARA OBRAS DE ARTE | 2024-09-27 → 2024-11-13 (+47d) | 2024-09-28 → 2024-11-14 (+47d) | 1.5d → 1d | 47.83d → 20.67d | 1.08.05 FS+0.5d → 1.08.05 FS+1d |
| 1.08.08 | RELLENO ESTRUCTURAL PARA OBRAS DE ARTE CON MATERIAL PROPIO | 2024-10-12 → 2024-11-15 (+34d) | 2024-10-16 → 2024-11-19 (+34d) | 3.76d → 4d | 76.78d → 68.81d | 1.08.04 FS+0.5d → 1.08.07 FS+1d |
| 5 | **RETORNOS Q=100 A 1000 l/s** | 2024-09-30 → 2024-11-15 (+46d) | 2024-10-29 → 2024-12-13 (+45d) |  |  |  |
| 1 | **MOVIMIENTO DE TIERRAS** | 2024-09-30 → 2024-11-15 (+46d) | 2024-10-29 → 2024-12-13 (+45d) |  |  |  |
| 1.08.09 | EXCAVACIÓN ESTRUCTURAL PARA OBRAS DE ARTE | 2024-09-30 → 2024-11-15 (+46d) | 2024-10-11 → 2024-11-26 (+46d) | 9.5d → 8.67d | 47.83d → 20.67d | 1.08.07 FS+0.5d → 1.08.07 FS+1d |
| 1.08.11 | RELLENO ESTRUCTURAL PARA OBRAS DE ARTE CON MATERIAL PROPIO | 2024-10-12 → 2024-11-27 (+46d) | 2024-10-29 → 2024-12-13 (+45d) | 14.5d → 16d | 47.83d → 26.05d | 1.08.09 FS+0.5d → 1.08.09 FS+1d |
| 1.08.10 | CAMA DE ARENA | 2024-10-12 → 2024-11-27 (+46d) | 2024-10-14 → 2024-11-28 (+45d) | 1.5d → 0.5d | 51.33d → 51.5d | 1.08.09 FS+0.5d → 1.08.09 FS+1d |
| 6 | **INTERFERENCIAS** | 2024-09-17 → 2024-10-15 (+28d) | 2024-10-26 → 2024-12-11 (+46d) |  |  |  |
| 3 | **REPOSICION DE ESTRUCTURAS (PASE DE AGUA)** | 2024-10-12 → 2024-11-27 (+46d) | 2024-10-18 → 2024-12-03 (+46d) |  |  |  |
| 1.09.01 | DEMOLICIÓN DE ESTRUCTURAS EXISTENTES | 2024-10-12 → 2024-11-27 (+46d) | 2024-10-12 → 2024-11-27 (+46d) | 0.53d → 0.5d | 81.66d → 42d | 1.08.09 FS+0.53d → 1.08.09 FS+0.5d |
| 1.09.02 | REPOSICIÓN DE PASE DE AGUA TUBERÍA HDPE Ø=36" | 2024-10-14 → 2024-11-28 (+45d) | 2024-10-14 → 2024-11-28 (+45d) | 0.53d → 0.5d | 93.75d → 53.08d | 1.09.01 FS+0.48d → 1.09.01 FS+0.45d |
| 1.09.03 | REPOSICIÓN DE PASE DE AGUA TUBERÍA HDPE Ø=24" | 2024-10-15 → 2024-11-29 (+45d) | 2024-10-15 → 2024-11-29 (+45d) | 0.53d → 0.5d | 93.75d → 53.08d | 1.09.02 FS+0.53d → 1.09.02 FS+0.5d |
| 1.09.05 | SUMINISTRO Y MONTAJE DE PANELES DE C°A° 1.9mx1.0mx0.20m EN PASE DE AGUA | 2024-10-16 → 2024-11-30 (+45d) | 2024-10-16 → 2024-11-30 (+45d) | 0.53d → 0.5d | 93.75d → 53.08d | 1.09.03 FS+0.5d → 1.09.04 FS+0.5d |
| 1.09.06 | SUMINISTRO Y MONTAJE DE PANELES DE C°A° 1.6mx1.0mx0.20m EN PASE DE AGUA | 2024-10-17 → 2024-12-02 (+46d) | 2024-10-17 → 2024-12-02 (+46d) | 0.53d → 0.5d | 93.75d → 53.08d | 1.09.05 SS+1.06d → 1.09.05 SS+1d |
| 1.09.07 | SUMINISTRO Y MONTAJE DE PANELES DE C°A° 1.8mx1.0mx0.20m EN PASE DE AGUA | 2024-10-18 → 2024-12-03 (+46d) | 2024-10-18 → 2024-12-03 (+46d) | 0.53d → 0.5d | 93.75d → 53.08d | 1.09.06 FS+0.53d → 1.09.06 FS+0.5d |
| 4 | **CABEZAL DE ENTRADA Y SALIDA (PASE DE AGUA)** | 2024-10-19 → 2024-12-04 (+46d) | 2024-10-25 → 2024-12-10 (+46d) |  |  |  |
| 1.09.10 | ENCOFRADO Y DESENCOFRADO NORMAL | 2024-10-19 → 2024-12-04 (+46d) | 2024-10-24 → 2024-12-09 (+46d) | 4.5d → 3d | 93.75d → 53.08d | 1.09.07 FS+0.5d → 1.09.07 FS+1d |
| 1.09.09 | CONCRETO 175 Kg/Cm2 | 2024-10-25 → 2024-12-10 (+46d) | 2024-10-25 → 2024-12-10 (+46d) |  | 93.75d → 53.08d | 1.09.10 FS+0.5d → 1.09.10 FS+0.8d |
| 5 | **CRUCE VEHICULAR (PASE DE AGUA)** | 2024-09-17 → 2024-10-15 (+28d) | 2024-10-01 → 2024-10-29 (+28d) |  |  |  |
| 1.09.14 | ACERO DE REFUERZO fy=4200 kg/cm2 | 2024-09-17 → 2024-10-15 (+28d) | 2024-09-20 → 2024-10-18 (+28d) | 3.5d → 3.17d | 113.64d → 85.67d | 1.08.03 SS+1.2d → 1.08.01 SS+1d |
| 1.09.13 | ENCOFRADO Y DESENCOFRADO NORMAL | 2024-09-21 → 2024-10-19 (+28d) | 2024-09-27 → 2024-10-25 (+28d) | 5.5d → 4.67d | 113.64d → 85.67d | 1.09.14 FS+0.5d → 1.09.14 FS+1d |
| 1.09.11 | CONCRETO f'c=280 kg/cm2 | 2024-09-28 → 2024-10-26 (+28d) | 2024-09-28 → 2024-10-26 (+28d) |  | 113.64d → 85.67d | 1.09.13 FS+0.5d → 1.09.13 FS+1d |
| 1.09.12 | CONCRETO CICLÓPEO F´C=170 Kg/cm2 | 2024-09-30 → 2024-10-28 (+28d) | 2024-09-30 → 2024-10-28 (+28d) | 0.59d → 0.5d | 113.64d → 85.67d | 1.09.11 FS+0.53d → 1.09.11 FS+0.5d |
| 1.09.15 | MONTAJE DE LOSA PREFABRICADA | 2024-10-01 → 2024-10-29 (+28d) | 2024-10-01 → 2024-10-29 (+28d) | 0.53d → 0.5d | 113.64d → 85.67d | 1.09.12 FS+0.53d → 1.09.12 FS+0.5d |
| 6 | **REPOSICION DE CANALES** | 2024-10-14 → 2024-11-28 (+45d) | 2024-10-26 → 2024-12-11 (+46d) |  |  |  |
| 1 | **MOVIMIENTO DE TIERRAS** | 2024-10-14 → 2024-11-28 (+45d) | 2024-10-26 → 2024-12-11 (+46d) |  |  |  |

| ID | Task | Start | Finish | Duration | Total float | Predecessors | Other |
| --- | --- | --- | --- | --- | --- | --- | --- |
| 1.09.16 | DEMOLICION DE ESTRUCTURAS EXISTENTES | 2024-10-14 → 2024-11-28 (+45d) | 2024-10-23 → 2024-12-07 (+45d) | 8.5d → 7.67d | 81.66d → 42d | 1.09.01 FS+0.5d → 1.09.01 FS+1d |  |
| 1.09.17 | EXCAVACIÓN EN TERRENO NATURAL CON EQUIPO | 2024-10-24 → 2024-12-09 (+46d) | 2024-10-24 → 2024-12-09 (+46d) | 0.53d → 0.5d | 81.66d → 42d | 1.09.16 FS+0.53d → 1.09.16 FS+0.5d |  |
| 1.09.18 | RELLENO ESTRUCTURAL PARA OBRAS DE ARTE CON MATERIAL PROPIO | 2024-10-25 → 2024-12-10 (+46d) | 2024-10-26 → 2024-12-11 (+46d) | 1.06d → 1d | 93.31d → 52.17d | 1.09.17 FS+0.53d → 1.09.17 FS+0.5d |  |
| 5 | **TRANSPORTE DE MATERIAL** |  | 2025-01-16 → 2025-02-08 (+23d) |  |  |  |  |
| 1.09.21 | TRANSPORTE DE MATERIAL EXCEDENTE |  | 2024-10-28 → 2025-02-08 (+103d) | 276.59d → 341.89d | 90.96d → 6.22d | 1.07.10 SS → 1.07.05 SS |  |
| 1.09.20 | TRANSPORTE DE ROCA | 2023-12-11 → 2023-12-27 (+16d) | 2024-12-23 → 2024-12-16 (-7d) | 314d → 278.66d | 45.05d → 48.33d | COLOCACION Y ACOMODO DE ROCA EN UÑA DE DIQUE A2-I-01-B SS-1d, 1.07.64 FF → 1.03.01 SS-3d |  |
| 1.09.19 | TRANSPORTE DE MATERIAL GRANULAR | 2023-12-13 → 2024-02-28 (+77d) | 2025-01-16 → 2025-01-02 (-14d) | 331.5d → 240.33d | 25.81d → 36.51d | 1.07.36 SS+0.2d, 1.07.53 FF → 1.07.44 SS-8d |  |
| 7 | **ARQUITECTURA Y PAISAJISMO** | 2024-10-25 → 2024-12-10 (+46d) | 2024-11-09 → 2024-12-24 (+45d) |  |  |  |  |
| 1 | **MOVIMIENTO DE TIERRAS** | 2024-10-25 → 2024-12-10 (+46d) | 2024-10-29 → 2024-12-13 (+45d) |  |  |  |  |
| 1.09.22 | EXCAVACIÓN MANUAL PARA INSTALACIÓN DE BORDILLOS Y CIMENTACIONES | 2024-10-25 → 2024-12-10 (+46d) | 2024-10-26 → 2024-12-11 (+46d) | 1.5d → 1d | 81.66d → 42d |  |  |
| 1.09.23 | EXCAVACIÓN PARA MEJORAMIENTO DE SUELO CON TIERRA VEGETAL | 2024-10-28 → 2024-12-12 (+45d) | 2024-10-28 → 2024-12-12 (+45d) | 0.5d → 1d | 90.9d → 49.67d | 1.09.22 FS+0.5d, 1.09.21 FF → 1.09.22 FS+0.5d |  |
| 1.09.24 | ELIMINACION DE MATERIAL EXCEDENTE (DME´S) | 2024-10-29 → 2024-12-13 (+45d) | 2024-10-29 → 2024-12-13 (+45d) |  | 90.9d → 49.67d |  |  |
| 2 | **PAVIMENTOS, RECUBRIMIENTOS Y BORDILLOS** | 2024-10-28 → 2024-12-12 (+45d) | 2024-11-09 → 2024-12-24 (+45d) |  |  |  |  |
| 1.09.27 | BORDILLOS DE PIEDRA DEL LUGAR | 2024-10-28 → 2024-12-12 (+45d) | 2024-10-30 → 2024-12-14 (+45d) | 2.65d → 2.5d | 81.66d → 42d | 1.09.22 FS+0.53d → 1.09.22 FS+0.5d |  |
| 1.09.25 | PISO DE GRAVILLA | 2024-10-31 → 2024-12-16 (+46d) | 2024-10-31 → 2024-12-16 (+46d) | 0.53d → 0.5d | 81.66d → 42d | 1.09.27 FS+0.53d → 1.09.27 FS+0.5d |  |
| 1.09.26 | RECUBRIMIENTO DE PIEDRA DEL LUGAR e=0.05cm | 2024-11-02 → 2024-12-17 (+45d) | 2024-11-09 → 2024-12-24 (+45d) | 6.5d → 5.67d | 81.66d → 42d |  |  |
| 8 | **PROGRAMA DE CIERRE DE OBRA** | 2023-11-28 → 2023-12-04 (+6d) |  |  |  |  |  |
| 01.10.01 | ACONDICIONAMIENTO DE DEPÓSITOS DE MATERIALES EXCEDENTES (DME) | 2023-11-28 → 2023-12-04 (+6d) | 2025-01-06 → 2025-02-13 (+38d) | 333.5d → 336.56d | 34.67d → 1.89d | A1040 SS-0.4d → 1.07.02 SS+5d |  |
| 01.10.02 | RESTAURACIÓN DE ÁREAS DE INSTALACIONES PROVISIONALES |  | 2025-02-07 → 2025-02-08 (+1d) | 6.41d → 7.94d |  | 1.07.21 FS+8d → 1.07.21 FS+15d |  |
| 01.10.03 | DESMOVILIZACIÓN | 2025-02-08 → 2025-02-10 (+2d) |  | 5.9d → 5.67d |  | 1.09.26 FF, 1.07.22 FF, 1.07.20 FF, 1.07.19 FF, 1.07.18 FF, PERFILADO Y COMPACTACIÓN EN ZONA DE CORTE EN CORONA INTERFERENCIA SEDACHIMBOTE FF, PERFILADO Y COMPACTACIÓN EN ZONA DE CORTE EN CORONA INTERFERENCIA QUAVI FF, PERFILADO Y COMPACTACIÓN EN ZONA DE CORTE EN CORONA LIBERACIÓN PREDIAL LI FF, PERFILADO Y COMPACTACIÓN EN ZONA DE CORTE EN CORONA LIBERACIÓN PREDIAL LD FF, 1.01.03 FF, 1.05.08 FF, 1.04.47 FF, 1.07.56 FF, 01.02.02 FF, 01.10.02 FS+1.5d, 01.10.01 FF, 1.04.03 FF, 1.04.09 FF, 1.04.12 FF, 1.04.29 FF, 1.04.34 FF, 1.04.39 FF, 1.04.41 FF, 1.04.15 FF, 1.05.01, 1.05.02 FF, 1.06.02 FF, 1.06.03 FF, 1.07.01 FF, 1.07.04 FF, 1.07.55 FF, 1.09.09 FF, 1.09.15 FF, 1.09.18 FF, 1.09.19 FF, 1.09.20 FF, 1.09.24 FF → 01.10.02 | was named DESMOVILIZACIÓN DE EQUIPOS |
